# Wingtip Toys Werbespot 2

Schedule from MS Project, 2008-01-07 to 2008-01-30.
Videoproduktionsplan
Industriefilm GmbH

## Calendars

- Standard: Mon-Fri 08:00-12:00, 13:00-17:00; Sat-Sun off. Exceptions (off unless hours are given): 2008-01-28 (Betriebsausflug).

## Resources

| Resource | Unit | Rate | Notes |
| --- | --- | --- | --- |
| Klara Hektor |  | 10 |  |
| Peter Henze |  | 15.5 |  |
| Petra Kelly |  | 20 | Frau Kelly ist spezialisiert auf Lichteffekte. |
| Jan Kurz |  | 22 |  |
| Elektriker |  | 22 |  |
| Mini-DV Camcorder |  | 6.25 |  |
| Kamerawagen |  |  |  |
| Labor |  | 25 |  |
| Videokassette | 30-Min.-Kassette | 5 |  |
| Reisen |  |  |  |
| Hans Schmitz |  | 22 |  |
| Michael Braun |  | 18.75 |  |
| Johann Müller |  | 10 |  |
| Patrizia Mintz |  | 9.4 |  |
| Antonio Ganio |  | 15.5 |  |
| 600-Watt-Lampe |  | 2.5 |  |
| Reflektor-Kit |  |  |  |
| Verpflegung |  |  |  |

## Schedule

| ID | WBS | Task | Type | Duration | Start | Finish | Predecessors | Total slack |
| --- | --- | --- | --- | --- | --- | --- | --- | --- |
| 1 | 1 | **Vorproduktion** |  | 12d | 2008-01-07 | 2008-01-22 |  | 0d |
| 2 | 1.1 | Drehbuch entwickeln |  | 5d | 2008-01-07 | 2008-01-11 |  | 0d |
| 3 | 1.2 | Produktionsablauf festlegen |  | 3d | 2008-01-14 | 2008-01-16 | 2 | 0d |
| 4 | 1.3 | Drehorte festlegen |  | 2d | 2008-01-17 | 2008-01-18 | 3 | 0d |
| 5 | 1.4 | Vorsprechen abhalten |  | 2d | 2008-01-21 | 2008-01-22 | 4 | 0d |
| 6 | 1.5 | Produktionsvorbereitung abgeschlossen! | milestone | 0d | 2008-01-22 | 2008-01-22 | 5 | 0d |
| 7 | 2 | **Produktion** |  | 5d | 2008-01-23 | 2008-01-30 | 1 | 0d |
| 8 | 2.1 | Proben |  | 2d | 2008-01-23 | 2008-01-24 |  | 0d |
| 9 | 2.2 | Video drehen |  | 2d | 2008-01-25 | 2008-01-29 | 8 | 0d |
| 10 | 2.3 | Filmmaterial loggen |  | 1d | 2008-01-30 | 2008-01-30 | 9 | 0d |

Notes:
- 4: Innen- und Außenaufnahmen
