# Wingtip Toys Werbespot

Schedule from MS Project, 2008-01-07 to 2008-02-01, costs in €.
Videoproduktionsplan
Industriefilm GmbH

## Calendars

- Standard: Mon-Fri 08:00-12:00, 13:00-17:00; Sat-Sun off. Exceptions (off unless hours are given): 2008-01-28 (Betriebsausflug).

## Resources

| Resource | Unit | Rate | Notes |
| --- | --- | --- | --- |
| Klara Hektor |  | 10 |  |
| Peter Henze |  | 15.5 |  |
| Petra Kelly |  | 20 | Frau Kelly ist spezialisiert auf Lichteffekte. |
| Jan Kurz |  | 22 |  |
| Elektriker |  | 22 |  |
| Mini-DV Camcorder |  | 6.25 |  |
| Kamerawagen |  |  |  |
| Labor |  | 25 |  |
| Videokassette | 30-Min.-Kassette | 5 |  |
| Reisen |  |  |  |
| Hans Schmitz |  | 22 |  |
| Michael Braun |  | 18.75 |  |
| Johann Müller |  | 10 |  |
| Patrizia Mintz |  | 9.4 |  |
| Antonio Ganio |  | 15.5 |  |
| 600-Watt-Lampe |  | 2.5 |  |
| Reflektor-Kit |  |  |  |
| Verpflegung |  |  |  |
| Editing lab |  |  |  |
| Scott Cooper |  |  |  |
| Garrett R. Vargas |  |  |  |

## Schedule

| ID | WBS | Task | Type | Duration | Start | Finish | Predecessors | Total slack | Free slack | Resources | Work | Cost |
| --- | --- | --- | --- | --- | --- | --- | --- | --- | --- | --- | --- | --- |
| 1 | 1 | **Vorproduktion** |  | 10.5d | 2008-01-07 | 2008-01-21 |  | 0.25d | 0d |  | 168h | 2,843.2 |
| 2 | 1.1 | Drehbuch entwickeln |  | 2.5d | 2008-01-07 | 2008-01-09 |  | 0.25d | 0d | Antonio Ganio; Patrizia Mintz | 40h | 498 |
| 3 | 1.2 | Produktionsablauf festlegen |  | 5d | 2008-01-09 | 2008-01-16 | 2 | 0.25d | 0d | Klara Hektor; Patrizia Mintz | 48h | 465.6 |
| 4 | 1.3 | Drehorte festlegen |  | 1d | 2008-01-16 | 2008-01-17 | 3 | 0.25d | 0d | Antonio Ganio; Patrizia Mintz; Videokassette [4 30-Min.-Kassette]; Reisen [0.6%] | 16h | 719.2 |
| 5 | 1.4 | Vorsprechen abhalten |  | 2d | 2008-01-17 | 2008-01-21 | 4 | 0.25d | 0d | Antonio Ganio; Hans Schmitz; Johann Müller; Patrizia Mintz; Verpflegung [0.2%] | 64h | 1,160.4 |
| 6 | 1.5 | Produktionsvorbereitung abgeschlossen! | milestone | 0d | 2008-01-21 | 2008-01-21 | 5 | 0.25d |  |  |  |  |
| 7 | 2 | **Produktion** |  | 4.5d | 2008-01-21 | 2008-01-25 | 1 | 0d |  |  | 423h | 4,032.4 |
| 8 | 2.1 | Proben |  | 2d | 2008-01-21 | 2008-01-23 |  | 0.25d | 0d | Klara Hektor; Peter Henze; Jan Kurz; Patrizia Mintz; Petra Kelly; Antonio Ganio [50%]; Hans Schmitz; 600-Watt-Lampe [400%]; Kamerawagen [200%]; Mini-DV Camcorder; Reflektor-Kit; Videokassette [1 30-Min.-Kassette] | 189h | 1,537.6 |
| 9 | 2.2 | Video drehen |  | 1.75d | 2008-01-23 | 2008-01-24 | 8 | 0d |  | Klara Hektor; Peter Henze; Jan Kurz; Patrizia Mintz; Petra Kelly; Antonio Ganio [50%]; Hans Schmitz; 600-Watt-Lampe [400%]; Kamerawagen [200%]; Mini-DV Camcorder [300%]; Reflektor-Kit; Videokassette [16 30-Min.-Kassette]; Elektriker [200%] | 218h | 2,144.8 |
| 10 | 2.3 | Filmmaterial loggen |  | 1d | 2008-01-25 | 2008-01-25 | 9 | 0d |  | Michael Braun; Labor | 16h | 350 |
| 11 | 2.4 | Produktion fertig stellen | milestone | 0d | 2008-01-25 | 2008-01-25 | 10 | 0d |  |  |  |  |
| 12 | 3 | **Produktionsnachbereitung** |  | 3.5d | 2008-01-29 | 2008-02-01 | 7 | 0d |  |  | 76h | 1,638 |
| 13 | 3.1 | Film schneiden |  | 2.25d | 2008-01-29 | 2008-01-30 |  | 0d |  | Labor; Jan Kurz; Petra Kelly | 48h | 1,072 |
| 14 | 3.2 | Ton hinzufügen |  | 1.25d | 2008-01-30 | 2008-01-31 | 13 | 0d |  | Labor; Michael Braun; Jan Kurz | 24h | 526 |
| 15 | 3.3 | Master an Kunden übergeben |  | 4h | 2008-02-01 | 2008-02-01 | 14 | 0d |  | Klara Hektor | 4h | 40 |

Notes:
- 4: Innen- und Außenaufnahmen
