# Kurzfilmprojekt 7a

Schedule from MS Project, 2008-01-07 to 2008-10-24, costs in €.

## Calendars

- Standard: Mon-Fri 08:00-12:00, 13:00-17:00; Sat-Sun off.

## Resources

| Resource | Rate |
| --- | --- |
| Stefan Meier | 19.37 |
| Klara Hektor | 15.5 |
| Jonathan Perrera | 22 |
| Kim Schmitz | 24 |
| Michael Braun | 5.62 |
| Jan Miskowski | 18.75 |
| Max Meier | 18 |
| Dora Hermann | 13 |
| Erik Lang | 15 |
| Elektriker | 22 |
| Paul Born | 9.38 |
| Josef Mattes | 9.38 |
| Susanne Brenner | 9.38 |
| Frank Lee | 14 |
| Kerstin Heller | 9.4 |
| Thomas Bremer | 14 |
| 16-mm-Kamera | 6.25 |
| 500-Watt-Lampe | 2.5 |
| Joschi Rander | 12 |
| Melani Heuer | 17.5 |
| Tim Mahler | 14 |
| Kamerawagen | 50 |
| Erik Müller | 6.25 |
| Peter Henze | 9.38 |
| Anne L. Pape | 9.38 |
| Dolly | 9.38 |
| David Kampmann | 9.38 |
| Kran | 18.75 |
| Daniel Penn | 9.38 |
| Labor | 25 |
| Florian Voss | 22 |
| Michael Patten | 25 |
| Lisa Germer | 23.75 |
| Richard Lund | 15.62 |
| Mark Müller | 24 |

## Schedule

| ID | WBS | Task | Type | Duration | Start | Finish | Predecessors | Total slack | Resources | Work | Cost |
| --- | --- | --- | --- | --- | --- | --- | --- | --- | --- | --- | --- |
| 1 | 1 | **Produktionsvorbereitung** |  | 58.5d | 2008-01-07 | 2008-03-27 |  | 0d |  | 1172h | 22,102.5 |
| 2 | 1.1 | Drehbuch überarbeiten |  | 0.5w | 2008-01-07 | 2008-01-09 |  | 0d | Stefan Meier; Klara Hektor | 40h | 697.5 |
| 3 | 1.2 | Drehbuch in Teilaufgaben zerlegen |  | 1w | 2008-01-09 | 2008-01-16 | 2 | 0d | Stefan Meier; Jonathan Perrera | 80h | 1,655 |
| 4 | 1.3 | Produktionsablauf festlegen |  | 1mo | 2008-01-16 | 2008-02-13 | 3 | 0d | Stefan Meier; Kim Schmitz; Jonathan Perrera | 480h | 10,460 |
| 5 | 1.4 | Drehorte erkunden |  | 2w | 2008-02-13 | 2008-02-27 | 4 | 0d | Michael Braun; Jan Miskowski; Max Meier | 240h | 3,390 |
| 6 | 1.5 | Drehorte auswählen |  | 1w | 2008-02-27 | 2008-03-05 | 5 | 0d | Stefan Meier; Klara Hektor; Max Meier | 120h | 2,115 |
| 7 | 1.6 | Vorsprechen abhalten |  | 1w | 2008-03-05 | 2008-03-12 | 6 | 0d | Klara Hektor; Stefan Meier; Dora Hermann [50%] | 100h | 1,655 |
| 8 | 1.7 | Dreherlaubnis beschaffen |  | 1w | 2008-03-12 | 2008-03-19 | 7 | 0d | Kim Schmitz | 40h | 960 |
| 9 | 1.8 | Kameraausrüstung reservieren |  | 3d | 2008-03-19 | 2008-03-24 | 8 | 0d | Jan Miskowski; Erik Lang | 48h | 810 |
| 10 | 1.9 | Tonausrüstung reservieren |  | 3d | 2008-03-24 | 2008-03-27 | 9 | 0d | Erik Lang | 24h | 360 |
| 11 | 1.10 | Produktionsvorbereitung abschließen | milestone | 0d | 2008-03-27 | 2008-03-27 | 10 | 0d |  |  |  |
| 12 | 2 | **Produktion** |  | 52.22d | 2008-03-27 | 2008-06-09 | 1 | 0d |  | 2231h | 27,221.84 |
| 13 | 2.1 | **Szene 7** |  | 5.4d | 2008-03-27 | 2008-04-03 |  | 0d |  | 228h | 2,939.5 |
| 14 | 2.1.1 | Szene 7 einrichten |  | 1.2d | 2008-03-27 | 2008-03-28 |  | 0d | Michael Braun; Max Meier; Elektriker [50%] | 24h | 332.4 |
| 15 | 2.1.2 | Szene 7 proben |  | 8h | 2008-03-28 | 2008-03-31 | 14 | 0d | Stefan Meier; Michael Braun; Paul Born [50%]; Josef Mattes; Susanne Brenner; Jan Miskowski | 44h | 537.5 |
| 16 | 2.1.3 | Szene 7 drehen |  | 8h | 2008-03-31 | 2008-04-01 | 15 | 0d | Stefan Meier; Michael Braun; Josef Mattes; Susanne Brenner; Frank Lee; Kerstin Heller; Thomas Bremer; 16-mm-Kamera [300%]; 500-Watt-Lampe [200%]; Joschi Rander; Melani Heuer; Tim Mahler; Jan Miskowski; Kamerawagen | 136h | 1,737.2 |
| 17 | 2.1.4 | Szene 7 Ergebnisse prüfen |  | 1.2d | 2008-04-01 | 2008-04-02 | 16 | 0d | Michael Braun; Max Meier; Elektriker [50%] | 24h | 332.4 |
| 18 | 2.1.5 | Szene 7 Tagesproduktion weiterverarbeiten |  | 1d | 2008-04-02 | 2008-04-03 | 17 | 0d |  |  |  |
| 19 | 2.2 | **Szene 3** |  | 4d | 2008-04-03 | 2008-04-09 | 13 | 0d |  | 268h | 3,238.2 |
| 20 | 2.2.1 | Szene 3 einrichten |  | 1d | 2008-04-03 | 2008-04-04 |  | 0d | Michael Braun; Max Meier; Elektriker | 24h | 365 |
| 21 | 2.2.2 | Szene 3 proben |  | 1d | 2008-04-04 | 2008-04-07 | 20 | 0d | Stefan Meier; Michael Braun; Erik Müller; Peter Henze; Anne L. Pape; Josef Mattes; Jan Miskowski | 56h | 625 |
| 22 | 2.2.3 | Szene 3 drehen |  | 8h | 2008-04-07 | 2008-04-08 | 21 | 0d | Stefan Meier; Michael Braun; Erik Müller; Peter Henze; Anne L. Pape; Josef Mattes; Tim Mahler; Melani Heuer; Dora Hermann [50%]; Kerstin Heller; 16-mm-Kamera [200%]; 500-Watt-Lampe [400%]; Dolly; Frank Lee; Jan Miskowski; Thomas Bremer; Kamerawagen | 164h | 1,883.2 |
| 23 | 2.2.4 | Szene 3 Ergebnisse prüfen |  | 1d | 2008-04-08 | 2008-04-09 | 22 | 0d | Michael Braun; Max Meier; Elektriker | 24h | 365 |
| 24 | 2.2.5 | Szene 3 Tagesproduktion weiterverarbeiten |  | 1d | 2008-04-08 | 2008-04-09 | 22 | 0d |  |  |  |

| ID | WBS | Task | Duration | Start | Finish | Predecessors | Total slack | Resources | Work | Cost |
| --- | --- | --- | --- | --- | --- | --- | --- | --- | --- | --- |
| 25 | 2.3 | **Szene 1** | 6d | 2008-04-09 | 2008-04-17 | 19 | 0d |  | 324h | 4,587.2 |
| 26 | 2.3.1 | Szene 1 einrichten | 3d | 2008-04-09 | 2008-04-14 |  | 0d | Michael Braun; Max Meier; Elektriker [200%] | 96h | 1,623 |
| 27 | 2.3.2 | Szene 1 proben | 1d | 2008-04-14 | 2008-04-15 | 26 | 0d | Stefan Meier; Michael Braun; Paul Born [50%]; David Kampmann; Erik Müller; Susanne Brenner; Jan Miskowski | 52h | 587.5 |
| 28 | 2.3.3 | Szene 1 drehen | 8h | 2008-04-15 | 2008-04-16 | 27 | 0d | Stefan Meier; Michael Braun; Paul Born [50%]; David Kampmann; Erik Müller; Susanne Brenner; Tim Mahler; Frank Lee; Melani Heuer; Dora Hermann [50%]; Kerstin Heller; Thomas Bremer; 16-mm-Kamera [300%]; 500-Watt-Lampe; Jan Miskowski; Dolly; Kamerawagen | 144h | 1,835.7 |
| 29 | 2.3.4 | Szene 1 Ergebnisse prüfen | 1d | 2008-04-16 | 2008-04-17 | 28 | 0d | Michael Braun; Max Meier; Elektriker [200%] | 32h | 541 |
| 30 | 2.3.5 | Szene 1 Tagesproduktion weiterverarbeiten | 1d | 2008-04-16 | 2008-04-17 | 28 | 0d |  |  |  |
| 31 | 2.4 | **Szene 2** | 4d | 2008-04-17 | 2008-04-23 | 25 | 0d |  | 138h | 1,906.1 |
| 32 | 2.4.1 | Szene 2 einrichten | 1d | 2008-04-17 | 2008-04-18 |  | 0d | Michael Braun; Max Meier; Elektriker | 24h | 365 |
| 33 | 2.4.2 | Szene 2 proben | 8h | 2008-04-18 | 2008-04-21 | 32 | 0d | Stefan Meier; Dora Hermann [50%]; David Kampmann; Anne L. Pape; Jan Miskowski | 36h | 507 |
| 34 | 2.4.3 | Szene 2 drehen | 4h | 2008-04-21 | 2008-04-22 | 33 | 0d | Stefan Meier; Dora Hermann [50%]; Anne L. Pape; Tim Mahler; Frank Lee; Kerstin Heller; Thomas Bremer; 16-mm-Kamera [200%]; 500-Watt-Lampe [300%]; Jan Miskowski; David Kampmann; Kamerawagen; Kran; Dolly | 66h | 851.6 |
| 35 | 2.4.4 | Szene 2 Ergebnisse prüfen | 0.5d | 2008-04-22 | 2008-04-22 | 34 | 0d | Michael Braun; Max Meier; Elektriker | 12h | 182.5 |
| 36 | 2.4.5 | Szene 2 Tagesproduktion weiterverarbeiten | 1d | 2008-04-22 | 2008-04-23 | 35 | 0d |  |  |  |
| 37 | 2.5 | **Szene 5** | 5.5d | 2008-04-23 | 2008-05-01 | 31 | 0d |  | 280h | 3,354.7 |
| 38 | 2.5.1 | Szene 5 einrichten | 2.5d | 2008-04-23 | 2008-04-28 |  | 0d | Michael Braun; Max Meier | 40h | 472.5 |
| 39 | 2.5.2 | Szene 5 proben | 1d | 2008-04-28 | 2008-04-29 | 38 | 0d | Stefan Meier; Michael Braun; Erik Müller; David Kampmann; Susanne Brenner; Daniel Penn; Anne L. Pape; Jan Miskowski [50%] | 60h | 625 |
| 40 | 2.5.3 | Szene 5 drehen | 8h | 2008-04-29 | 2008-04-30 | 39 | 0d | Stefan Meier; Michael Braun; Erik Müller; David Kampmann; Susanne Brenner; Daniel Penn; Anne L. Pape; Tim Mahler; Frank Lee; Melani Heuer; Dora Hermann [50%]; Kerstin Heller; Thomas Bremer; 16-mm-Kamera [200%]; 500-Watt-Lampe [200%]; Kran; Jan Miskowski; Kamerawagen; Dolly | 164h | 2,068.2 |
| 41 | 2.5.4 | Szene 5 Ergebnisse prüfen | 1d | 2008-04-30 | 2008-05-01 | 40 | 0d | Michael Braun; Max Meier | 16h | 189 |
| 42 | 2.5.5 | Szene 5 Tagesproduktion weiterverarbeiten | 1d | 2008-04-30 | 2008-05-01 | 40 | 0d |  |  |  |
| 43 | 2.6 | **Szene 6** | 13.57d | 2008-05-01 | 2008-05-20 | 37 | 0d |  | 556h | 5,919.14 |
| 44 | 2.6.1 | Szene 6 einrichten | 6d | 2008-05-01 | 2008-05-09 |  | 0d | Michael Braun; Max Meier | 96h | 1,134 |
| 45 | 2.6.2 | Szene 6 proben | 2d | 2008-05-09 | 2008-05-13 | 44 | 0d | Stefan Meier; Michael Braun; Dora Hermann [50%]; Paul Born [50%]; David Kampmann; Susanne Brenner; Anne L. Pape; Peter Henze; Daniel Penn; Jan Miskowski [50%] | 136h | 1,479 |
| 46 | 2.6.3 | Szene 6 drehen | 12.54h | 2008-05-13 | 2008-05-14 | 45 | 0d | Stefan Meier; Michael Braun; Dora Hermann [50%]; Paul Born [50%]; David Kampmann; Susanne Brenner; Anne L. Pape; Peter Henze; Daniel Penn; Frank Lee; Melani Heuer; Kerstin Heller; Thomas Bremer; 16-mm-Kamera [300%]; 500-Watt-Lampe [300%]; Dolly; Kran; Joschi Rander; Tim Mahler | 276h | 2,739.14 |
| 47 | 2.6.4 | Szene 6 Ergebnisse prüfen | 3d | 2008-05-14 | 2008-05-19 | 46 | 0d | Michael Braun; Max Meier | 48h | 567 |
| 48 | 2.6.5 | Szene 6 Tagesproduktion weiterverarbeiten | 1d | 2008-05-19 | 2008-05-20 | 47 | 0d |  |  |  |

| ID | WBS | Task | Duration | Start | Finish | Predecessors | Total slack | Resources | Work | Cost |
| --- | --- | --- | --- | --- | --- | --- | --- | --- | --- | --- |
| 49 | 2.7 | **Szene 8** | 9d | 2008-05-20 | 2008-06-02 | 43 | 0d |  | 346h | 4,122.45 |
| 50 | 2.7.1 | Szene 8 einrichten | 3d | 2008-05-20 | 2008-05-23 |  | 0d | Michael Braun; Max Meier | 48h | 567 |
| 51 | 2.7.2 | Szene 8 proben | 2.5d | 2008-05-23 | 2008-05-28 | 50 | 0d | Stefan Meier; Michael Braun; Dora Hermann [50%]; Paul Born [50%]; David Kampmann; Susanne Brenner; Erik Müller; Jan Miskowski [50%] | 130h | 1,411.25 |
| 52 | 2.7.3 | Szene 8 drehen | 8h | 2008-05-28 | 2008-05-29 | 51 | 0d | Stefan Meier; Michael Braun; Dora Hermann [50%]; Paul Born [50%]; David Kampmann; Susanne Brenner; Erik Müller; Tim Mahler; Frank Lee; Melani Heuer; Kerstin Heller; Thomas Bremer; 16-mm-Kamera [200%]; 500-Watt-Lampe; Dolly [200%]; Kamerawagen; Kran | 144h | 1,860.7 |
| 53 | 2.7.4 | Szene 8 Ergebnisse prüfen | 1.5d | 2008-05-29 | 2008-05-30 | 52 | 0d | Michael Braun; Max Meier | 24h | 283.5 |
| 54 | 2.7.5 | Szene 8 Tagesproduktion weiterverarbeiten | 1d | 2008-05-30 | 2008-06-02 | 53 | 0d |  |  |  |
| 55 | 2.8 | **Szene 4** | 4.75d | 2008-06-02 | 2008-06-09 | 49 | 0d |  | 91h | 1,154.55 |
| 56 | 2.8.1 | Szene 4 einrichten | 1.5d | 2008-06-02 | 2008-06-04 |  | 0d | Michael Braun; Max Meier | 24h | 283.5 |
| 57 | 2.8.2 | Szene 4 proben | 4h | 2008-06-04 | 2008-06-04 | 56 | 0d | Stefan Meier; Dora Hermann [50%]; Anne L. Pape; Josef Mattes; Jan Miskowski [50%] | 16h | 216 |
| 58 | 2.8.3 | Szene 4 drehen | 2h | 2008-06-04 | 2008-06-05 | 57 | 0d | Stefan Meier; Dora Hermann [50%]; Anne L. Pape; Josef Mattes; Frank Lee; Melani Heuer; Kerstin Heller; 16-mm-Kamera [200%]; 500-Watt-Lampe [200%]; Jan Miskowski; Thomas Bremer; Kamerawagen | 27h | 371.55 |
| 59 | 2.8.4 | Szene 4 Ergebnisse prüfen | 1.5d | 2008-06-05 | 2008-06-06 | 58 | 0d | Michael Braun; Max Meier | 24h | 283.5 |
| 60 | 2.8.5 | Szene 4 Tagesproduktion weiterverarbeiten | 1d | 2008-06-06 | 2008-06-09 | 59 | 0d |  |  |  |
| 61 | 3 | **Produktionsnachbereitung** | 98.75d | 2008-06-09 | 2008-10-24 | 12 | 0d |  | 1830h | 35,851.33 |
| 62 | 3.1 | Filmmaterial sichten | 8.5d | 2008-06-09 | 2008-06-20 |  | 0d | Labor; Florian Voss | 136h | 3,196 |
| 63 | 3.2 | Sprechtext grob festlegen | 12d | 2008-06-20 | 2008-07-08 | 62 | 0d | David Kampmann; Michael Patten | 192h | 3,300 |
| 64 | 3.3 | Filmsequenzen schriftlich bearbeiten | 10d | 2008-07-08 | 2008-07-22 | 63 | 0d | Klara Hektor; Kim Schmitz; Lisa Germer; Richard Lund | 320h | 6,310 |
| 65 | 3.4 | Grobschnitt | 5d | 2008-07-22 | 2008-07-29 | 64 | 0d | Klara Hektor; Richard Lund | 80h | 1,245 |
| 66 | 3.5 | Detailschnitt | 10d | 2008-07-29 | 2008-08-12 | 65 | 0d | Klara Hektor; Richard Lund; Lisa Germer; Kim Schmitz; Labor | 400h | 8,310 |
| 67 | 3.6 | Formelle Abnahmevorführung | 1d | 2008-08-12 | 2008-08-13 | 66 | 0d | Klara Hektor; Michael Braun; Mark Müller; Stefan Meier | 32h | 516 |
| 68 | 3.7 | Text aufnehmen | 13.33d | 2008-08-13 | 2008-09-01 | 67 | 0d | David Kampmann; Michael Patten; Stefan Meier | 320h | 5,733.33 |
| 69 | 3.8 | Vor- und Abspann fertig stellen | 1w | 2008-09-01 | 2008-09-08 | 68 | 0d | Michael Braun; Michael Patten; Labor | 120h | 2,225 |
| 70 | 3.9 | Soundtrack fertig stellen | 16d | 2008-09-08 | 2008-09-30 | 69 | 0d | Michael Patten | 128h | 3,200 |
| 71 | 3.10 | Negativ ziehen | 3.25d | 2008-09-30 | 2008-10-03 | 70 | 0d | Florian Voss | 26h | 572 |
| 72 | 3.11 | Synchronisationsmaster auf Audiokassette speichern | 12d | 2008-10-03 | 2008-10-21 | 71 | 0d | Dora Hermann [50%] | 48h | 624 |
| 73 | 3.12 | Film- und Audiomaster archivieren | 1.67d | 2008-10-21 | 2008-10-23 | 72 | 0d | Dora Hermann [50%]; Labor | 20h | 420 |
| 74 | 3.13 | Fertige Filme an Vertrieb ausliefern | 1d | 2008-10-23 | 2008-10-24 | 73 | 0d | Michael Patten | 8h | 200 |
