# Kurzfilmprojekt 8afinal

Schedule from MS Project, 2008-01-07 to 2008-10-22, costs in €.

## Calendars

- Standard: Mon-Fri 08:00-12:00, 13:00-17:00; Sat-Sun off.
- Nachtaufnahmen: Mon-Fri 17:00-23:00; Sat-Sun off.

## Resources

| Resource | Group | Unit | Rate |
| --- | --- | --- | --- |
| Stefan Meier |  |  | 19.37 |
| Klara Hektor |  |  | 15.5 |
| Jonathan Perrera |  |  | 22 |
| Kim Schmitz |  |  | 24 |
| Michael Braun |  |  | 5.62 |
| Jan Miskowski |  |  | 18.75 |
| Max Meier |  |  | 18 |
| Dora Hermann |  |  | 13 |
| Erik Lang |  |  | 15 |
| Elektriker |  |  | 22 |
| Paul Born |  |  | 9.38 |
| Josef Mattes |  |  | 9.38 |
| Susanne Brenner |  |  | 9.38 |
| Frank Lee |  |  | 14 |
| Kerstin Heller |  |  | 9.4 |
| Thomas Bremer |  |  | 14 |
| 16-mm-Kamera |  |  | 6.25 |
| 500-Watt-Lampe |  |  | 2.5 |
| Joschi Rander |  |  | 12 |
| Melani Heuer |  |  | 17.5 |
| Tim Mahler |  |  | 14 |
| Kamerawagen |  |  | 50 |
| Erik Müller |  |  | 6.25 |
| Peter Henze |  |  | 9.38 |
| Anne L. Pape |  |  | 9.38 |
| Dolly |  |  | 9.38 |
| David Kampmann |  |  | 9.38 |
| Kran |  |  | 18.75 |
| Daniel Penn |  |  | 9.38 |
| Labor |  |  | 25 |
| Florian Voss |  |  | 22 |
| Michael Patten |  |  | 25 |
| Lisa Germer |  |  | 23.75 |
| Richard Lund |  |  | 15.62 |
| Mark Müller |  |  | 24 |
| 16-mm-Film | Film und Labor | 100 Feet | 25 |

## Schedule

| ID | WBS | Task | Type | Duration | Start | Finish | Predecessors | Total slack | Free slack | Constraint | Deadline | Resources | Work | Cost |
| --- | --- | --- | --- | --- | --- | --- | --- | --- | --- | --- | --- | --- | --- | --- |
| 1 | 1 | **Produktionsvorbereitung** |  | 57.5d | 2008-01-07 | 2008-03-26 |  | 0.1d | 0d |  |  |  | 1232h | 23,740 |
| 2 | 1.1 | Drehbuch überarbeiten |  | 1w | 2008-01-07 | 2008-01-11 |  | 0.1d | 0d |  |  | Stefan Meier [50%]; Klara Hektor [50%] | 40h | 697.5 |
| 3 | 1.2 | Drehbuch in Teilaufgaben zerlegen |  | 1w | 2008-01-14 | 2008-01-18 | 2 | 0.1d | 0d |  |  | Stefan Meier; Jonathan Perrera | 80h | 1,655 |
| 4 | 1.3 | Produktionsablauf festlegen |  | 1mo | 2008-01-21 | 2008-02-19 | 3 | 0.1d | 0d |  |  | Stefan Meier; Kim Schmitz; Jonathan Perrera | 480h | 10,460 |
| 5 | 1.4 | Drehorte erkunden |  | 2w | 2008-02-20 | 2008-03-04 | 4 | 0.1d | 0d |  |  | Michael Braun; Jan Miskowski; Max Meier | 240h | 3,390 |
| 6 | 1.5 | Drehorte auswählen |  | 1w | 2008-03-05 | 2008-03-11 | 5 | 0.1d | 0d |  |  | Stefan Meier; Klara Hektor; Max Meier | 120h | 2,115 |
| 7 | 1.6 | Vorsprechen abhalten |  | 1w | 2008-03-12 | 2008-03-18 | 6 | 0.1d | 0d |  |  | Klara Hektor; Stefan Meier; Dora Hermann [50%] | 100h | 1,655 |
| 8 | 1.7 | Dreherlaubnis beschaffen |  | 1w | 2008-03-19 | 2008-03-25 | 7 | 0.1d | 0d |  |  | Kim Schmitz | 40h | 1,460 |
| 9 | 1.8 | Kameraausrüstung reservieren |  | 3d | 2008-03-21 | 2008-03-26 | 8FS-5% | 0.1d | 0d |  |  | Jan Miskowski; Erik Lang | 48h | 810 |
| 10 | 1.9 | Tonausrüstung reservieren |  | 3d | 2008-03-21 | 2008-03-26 | 9SS | 0.1d | 0d |  |  | Erik Lang | 24h | 360 |
| 11 | 1.10 | Produktionsvorbereitung abschließen | milestone | 0d | 2008-03-26 | 2008-03-26 | 10 | 0.1d |  |  | 2008-03-28 |  |  |  |
| 12 | 1.11 | **Terminplanungsmeeting** |  | 45.25d | 2008-01-14 | 2008-03-17 |  | 7.35d |  |  |  |  | 60h | 1,137.5 |
| 13 | 1.11.1 | Terminplanungsmeeting 1 |  | 2h | 2008-01-14 | 2008-01-14 |  | 52.35d |  | start no earlier than 2008-01-14 |  | Klara Hektor; Jonathan Perrera; Stefan Meier | 6h | 113.75 |
| 14 | 1.11.2 | Terminplanungsmeeting 2 |  | 2h | 2008-01-21 | 2008-01-21 |  | 47.35d |  | start no earlier than 2008-01-21 |  | Klara Hektor; Jonathan Perrera; Stefan Meier | 6h | 113.75 |
| 15 | 1.11.3 | Terminplanungsmeeting 3 |  | 2h | 2008-01-28 | 2008-01-28 |  | 42.35d |  | start no earlier than 2008-01-28 |  | Klara Hektor; Jonathan Perrera; Stefan Meier | 6h | 113.75 |
| 16 | 1.11.4 | Terminplanungsmeeting 4 |  | 2h | 2008-02-04 | 2008-02-04 |  | 37.35d |  | start no earlier than 2008-02-04 |  | Klara Hektor; Jonathan Perrera; Stefan Meier | 6h | 113.75 |
| 17 | 1.11.5 | Terminplanungsmeeting 5 |  | 2h | 2008-02-11 | 2008-02-11 |  | 32.35d |  | start no earlier than 2008-02-11 |  | Klara Hektor; Jonathan Perrera; Stefan Meier | 6h | 113.75 |
| 18 | 1.11.6 | Terminplanungsmeeting 6 |  | 2h | 2008-02-18 | 2008-02-18 |  | 27.35d |  | start no earlier than 2008-02-18 |  | Klara Hektor; Jonathan Perrera; Stefan Meier | 6h | 113.75 |
| 19 | 1.11.7 | Terminplanungsmeeting 7 |  | 2h | 2008-02-25 | 2008-02-25 |  | 22.35d |  | start no earlier than 2008-02-25 |  | Klara Hektor; Jonathan Perrera; Stefan Meier | 6h | 113.75 |
| 20 | 1.11.8 | Terminplanungsmeeting 8 |  | 2h | 2008-03-03 | 2008-03-03 |  | 17.35d |  | start no earlier than 2008-03-03 |  | Klara Hektor; Jonathan Perrera; Stefan Meier | 6h | 113.75 |
| 21 | 1.11.9 | Terminplanungsmeeting 9 |  | 2h | 2008-03-10 | 2008-03-10 |  | 12.35d |  | start no earlier than 2008-03-10 |  | Klara Hektor; Jonathan Perrera; Stefan Meier | 6h | 113.75 |
| 22 | 1.11.10 | Terminplanungsmeeting 10 |  | 2h | 2008-03-17 | 2008-03-17 |  | 7.35d |  | start no earlier than 2008-03-17 |  | Klara Hektor; Jonathan Perrera; Stefan Meier | 6h | 113.75 |
| 23 | 2 | **Produktion** |  | 51.82d | 2008-03-26 | 2008-06-06 | 1 | 0d |  |  |  |  | 2231h | 27,221.84 |
| 24 | 2.1 | **Szene 7** |  | 5.4d | 2008-03-26 | 2008-04-02 |  | 0.1d | 0d |  |  |  | 228h | 2,939.5 |
| 25 | 2.1.1 | Szene 7 einrichten |  | 1.2d | 2008-03-26 | 2008-03-27 |  | 0.1d | 0d |  |  | Michael Braun; Max Meier; Elektriker [50%] | 24h | 332.4 |
| 26 | 2.1.2 | Szene 7 proben |  | 8h | 2008-03-27 | 2008-03-28 | 25 | 0.1d | 0d |  |  | Stefan Meier; Michael Braun; Paul Born [50%]; Josef Mattes; Susanne Brenner; Jan Miskowski | 44h | 537.5 |
| 27 | 2.1.3 | Szene 7 drehen |  | 8h | 2008-03-28 | 2008-03-31 | 26 | 0.1d | 0d |  |  | Stefan Meier; Michael Braun; Josef Mattes; Susanne Brenner; Frank Lee; Kerstin Heller; Thomas Bremer; 16-mm-Kamera [300%]; 500-Watt-Lampe [200%]; Joschi Rander; Melani Heuer; Tim Mahler; Jan Miskowski; Kamerawagen | 136h | 1,737.2 |
| 28 | 2.1.4 | Szene 7 Ergebnisse prüfen |  | 1.2d | 2008-03-31 | 2008-04-01 | 27 | 0.1d | 0d |  |  | Michael Braun; Max Meier; Elektriker [50%] | 24h | 332.4 |
| 29 | 2.1.5 | Szene 7 Tagesproduktion weiterverarbeiten |  | 1d | 2008-04-01 | 2008-04-02 | 28 | 0.1d |  |  |  |  |  |  |

| ID | WBS | Task | Duration | Start | Finish | Predecessors | Total slack | Free slack | Constraint | Calendar | Resources | Work | Cost |
| --- | --- | --- | --- | --- | --- | --- | --- | --- | --- | --- | --- | --- | --- |
| 30 | 2.2 | **Szene 3** | 4d | 2008-04-02 | 2008-04-08 | 24 | 0.1d | 0d |  |  |  | 268h | 3,238.2 |
| 31 | 2.2.1 | Szene 3 einrichten | 1d | 2008-04-02 | 2008-04-03 |  | 0.1d | 0d | start no earlier than 2008-03-31 |  | Michael Braun; Max Meier; Elektriker | 24h | 365 |
| 32 | 2.2.2 | Szene 3 proben | 1d | 2008-04-03 | 2008-04-04 | 31 | 0.1d | 0d |  |  | Stefan Meier; Michael Braun; Erik Müller; Peter Henze; Anne L. Pape; Josef Mattes; Jan Miskowski | 56h | 625 |
| 33 | 2.2.3 | Szene 3 drehen | 8h | 2008-04-04 | 2008-04-07 | 32 | 0.1d | 0d |  |  | Stefan Meier; Michael Braun; Erik Müller; Peter Henze; Anne L. Pape; Josef Mattes; Tim Mahler; Melani Heuer; Dora Hermann [50%]; Kerstin Heller; 16-mm-Kamera [200%]; 500-Watt-Lampe [400%]; Dolly; Frank Lee; Jan Miskowski; Thomas Bremer; Kamerawagen | 164h | 1,883.2 |
| 34 | 2.2.4 | Szene 3 Ergebnisse prüfen | 1d | 2008-04-07 | 2008-04-08 | 33 | 0.1d |  |  |  | Michael Braun; Max Meier; Elektriker | 24h | 365 |
| 35 | 2.2.5 | Szene 3 Tagesproduktion weiterverarbeiten | 1d | 2008-04-07 | 2008-04-08 | 33 | 0.1d |  |  |  |  |  |  |
| 36 | 2.3 | **Szene 1** | 6d | 2008-04-08 | 2008-04-16 | 30 | 0.1d | 0d |  |  |  | 324h | 4,587.2 |
| 37 | 2.3.1 | Szene 1 einrichten | 3d | 2008-04-08 | 2008-04-11 |  | 0.1d | 0d |  |  | Michael Braun; Max Meier; Elektriker [200%] | 96h | 1,623 |
| 38 | 2.3.2 | Szene 1 proben | 1d | 2008-04-11 | 2008-04-14 | 37 | 0.1d | 0d |  |  | Stefan Meier; Michael Braun; Paul Born [50%]; David Kampmann; Erik Müller; Susanne Brenner; Jan Miskowski | 52h | 587.5 |
| 39 | 2.3.3 | Szene 1 drehen | 8h | 2008-04-14 | 2008-04-15 | 38 | 0.1d | 0d |  |  | Stefan Meier; Michael Braun; Paul Born [50%]; David Kampmann; Erik Müller; Susanne Brenner; Tim Mahler; Frank Lee; Melani Heuer; Dora Hermann [50%]; Kerstin Heller; Thomas Bremer; 16-mm-Kamera [300%]; 500-Watt-Lampe; Jan Miskowski; Dolly; Kamerawagen | 144h | 1,835.7 |
| 40 | 2.3.4 | Szene 1 Ergebnisse prüfen | 1d | 2008-04-15 | 2008-04-16 | 39 | 0.1d |  |  |  | Michael Braun; Max Meier; Elektriker [200%] | 32h | 541 |
| 41 | 2.3.5 | Szene 1 Tagesproduktion weiterverarbeiten | 1d | 2008-04-15 | 2008-04-16 | 39 | 0.1d |  |  |  |  |  |  |
| 42 | 2.4 | **Szene 2** | 3.6d | 2008-04-16 | 2008-04-22 | 36 | 0d |  |  |  |  | 138h | 1,906.1 |
| 43 | 2.4.1 | Szene 2 einrichten | 1d | 2008-04-16 | 2008-04-17 |  | 0.1d | 0d |  |  | Michael Braun; Max Meier; Elektriker | 24h | 365 |
| 44 | 2.4.2 | Szene 2 proben | 8h | 2008-04-17 | 2008-04-18 | 43 | 0.1d |  |  |  | Stefan Meier; Dora Hermann [50%]; David Kampmann; Anne L. Pape; Jan Miskowski | 36h | 507 |
| 45 | 2.4.3 | Szene 2 drehen | 4h | 2008-04-18 | 2008-04-18 | 44 | 0.25d | 0d |  | Nachtaufnahmen | Stefan Meier; Dora Hermann [50%]; Anne L. Pape; Tim Mahler; Frank Lee; Kerstin Heller; Thomas Bremer; 16-mm-Kamera [200%]; 500-Watt-Lampe [300%]; Jan Miskowski; David Kampmann; Kamerawagen; Kran; Dolly | 66h | 851.6 |
| 46 | 2.4.4 | Szene 2 Ergebnisse prüfen | 0.5d | 2008-04-21 | 2008-04-21 | 45 | 0d |  |  |  | Michael Braun; Max Meier; Elektriker | 12h | 182.5 |
| 47 | 2.4.5 | Szene 2 Tagesproduktion weiterverarbeiten | 1d | 2008-04-21 | 2008-04-22 | 46 | 0d |  |  |  |  |  |  |
| 48 | 2.5 | **Szene 5** | 5.5d | 2008-04-22 | 2008-04-29 | 42 | 0d |  |  |  |  | 280h | 3,354.7 |
| 49 | 2.5.1 | Szene 5 einrichten | 2.5d | 2008-04-22 | 2008-04-24 |  | 0d |  |  |  | Michael Braun; Max Meier | 40h | 472.5 |
| 50 | 2.5.2 | Szene 5 proben | 1d | 2008-04-25 | 2008-04-25 | 49 | 0d |  |  |  | Stefan Meier; Michael Braun; Erik Müller; David Kampmann; Susanne Brenner; Daniel Penn; Anne L. Pape; Jan Miskowski [50%] | 60h | 625 |
| 51 | 2.5.3 | Szene 5 drehen | 8h | 2008-04-28 | 2008-04-28 | 50 | 0d |  |  |  | Stefan Meier; Michael Braun; Erik Müller; David Kampmann; Susanne Brenner; Daniel Penn; Anne L. Pape; Tim Mahler; Frank Lee; Melani Heuer; Dora Hermann [50%]; Kerstin Heller; Thomas Bremer; 16-mm-Kamera [200%]; 500-Watt-Lampe [200%]; Kran; Jan Miskowski; Kamerawagen; Dolly | 164h | 2,068.2 |
| 52 | 2.5.4 | Szene 5 Ergebnisse prüfen | 1d | 2008-04-29 | 2008-04-29 | 51 | 0d |  |  |  | Michael Braun; Max Meier | 16h | 189 |
| 53 | 2.5.5 | Szene 5 Tagesproduktion weiterverarbeiten | 1d | 2008-04-29 | 2008-04-29 | 51 | 0d |  |  |  |  |  |  |

| ID | WBS | Task | Duration | Start | Finish | Predecessors | Total slack | Resources | Work | Cost |
| --- | --- | --- | --- | --- | --- | --- | --- | --- | --- | --- |
| 54 | 2.6 | **Szene 6** | 13.57d | 2008-04-30 | 2008-05-19 | 48 | 0d |  | 556h | 5,919.14 |
| 55 | 2.6.1 | Szene 6 einrichten | 6d | 2008-04-30 | 2008-05-07 |  | 0d | Michael Braun; Max Meier | 96h | 1,134 |
| 56 | 2.6.2 | Szene 6 proben | 2d | 2008-05-08 | 2008-05-09 | 55 | 0d | Stefan Meier; Michael Braun; Dora Hermann [50%]; Paul Born [50%]; David Kampmann; Susanne Brenner; Anne L. Pape; Peter Henze; Daniel Penn; Jan Miskowski [50%] | 136h | 1,479 |
| 57 | 2.6.3 | Szene 6 drehen | 12.54h | 2008-05-12 | 2008-05-13 | 56 | 0d | Stefan Meier; Michael Braun; Dora Hermann [50%]; Paul Born [50%]; David Kampmann; Susanne Brenner; Anne L. Pape; Peter Henze; Daniel Penn; Frank Lee; Melani Heuer; Kerstin Heller; Thomas Bremer; 16-mm-Kamera [300%]; 500-Watt-Lampe [300%]; Dolly; Kran; Joschi Rander; Tim Mahler | 276h | 2,739.14 |
| 58 | 2.6.4 | Szene 6 Ergebnisse prüfen | 3d | 2008-05-13 | 2008-05-16 | 57 | 0d | Michael Braun; Max Meier | 48h | 567 |
| 59 | 2.6.5 | Szene 6 Tagesproduktion weiterverarbeiten | 1d | 2008-05-16 | 2008-05-19 | 58 | 0d |  |  |  |
| 60 | 2.7 | **Szene 8** | 9d | 2008-05-19 | 2008-05-30 | 54 | 0d |  | 346h | 4,122.45 |
| 61 | 2.7.1 | Szene 8 einrichten | 3d | 2008-05-19 | 2008-05-22 |  | 0d | Michael Braun; Max Meier | 48h | 567 |
| 62 | 2.7.2 | Szene 8 proben | 2.5d | 2008-05-22 | 2008-05-27 | 61 | 0d | Stefan Meier; Michael Braun; Dora Hermann [50%]; Paul Born [50%]; David Kampmann; Susanne Brenner; Erik Müller; Jan Miskowski [50%] | 130h | 1,411.25 |
| 63 | 2.7.3 | Szene 8 drehen | 8h | 2008-05-27 | 2008-05-28 | 62 | 0d | Stefan Meier; Michael Braun; Dora Hermann [50%]; Paul Born [50%]; David Kampmann; Susanne Brenner; Erik Müller; Tim Mahler; Frank Lee; Melani Heuer; Kerstin Heller; Thomas Bremer; 16-mm-Kamera [200%]; 500-Watt-Lampe; Dolly [200%]; Kamerawagen; Kran | 144h | 1,860.7 |
| 64 | 2.7.4 | Szene 8 Ergebnisse prüfen | 1.5d | 2008-05-28 | 2008-05-29 | 63 | 0d | Michael Braun; Max Meier | 24h | 283.5 |
| 65 | 2.7.5 | Szene 8 Tagesproduktion weiterverarbeiten | 1d | 2008-05-29 | 2008-05-30 | 64 | 0d |  |  |  |
| 66 | 2.8 | **Szene 4** | 4.75d | 2008-05-30 | 2008-06-06 | 60 | 0d |  | 91h | 1,154.55 |
| 67 | 2.8.1 | Szene 4 einrichten | 1.5d | 2008-05-30 | 2008-06-03 |  | 0d | Michael Braun; Max Meier | 24h | 283.5 |
| 68 | 2.8.2 | Szene 4 proben | 4h | 2008-06-03 | 2008-06-03 | 67 | 0d | Stefan Meier; Dora Hermann [50%]; Anne L. Pape; Josef Mattes; Jan Miskowski [50%] | 16h | 216 |
| 69 | 2.8.3 | Szene 4 drehen | 2h | 2008-06-03 | 2008-06-03 | 68 | 0d | Stefan Meier; Dora Hermann [50%]; Anne L. Pape; Josef Mattes; Frank Lee; Melani Heuer; Kerstin Heller; 16-mm-Kamera [200%]; 500-Watt-Lampe [200%]; Jan Miskowski; Thomas Bremer; Kamerawagen | 27h | 371.55 |
| 70 | 2.8.4 | Szene 4 Ergebnisse prüfen | 1.5d | 2008-06-03 | 2008-06-05 | 69 | 0d | Michael Braun; Max Meier | 24h | 283.5 |
| 71 | 2.8.5 | Szene 4 Tagesproduktion weiterverarbeiten | 1d | 2008-06-05 | 2008-06-06 | 70 | 0d |  |  |  |
| 72 | 3 | **Produktionsnachbereitung** | 98.08d | 2008-06-06 | 2008-10-22 | 23 | 0d |  | 1718h | 33,721.5 |
| 73 | 3.1 | Filmmaterial sichten | 8.5d | 2008-06-06 | 2008-06-18 |  | 0d | Labor; Florian Voss | 136h | 3,196 |
| 74 | 3.2 | Sprechtext grob festlegen | 12d | 2008-06-18 | 2008-07-04 | 73 | 0d | David Kampmann; Michael Patten | 192h | 3,300 |
| 75 | 3.3 | Filmsequenzen schriftlich bearbeiten | 10d | 2008-07-04 | 2008-07-18 | 74 | 0d | Klara Hektor; Kim Schmitz; Lisa Germer; Richard Lund | 320h | 6,310 |
| 76 | 3.4 | Grobschnitt | 5d | 2008-07-18 | 2008-07-25 | 75 | 0d | Klara Hektor; Richard Lund | 80h | 1,245 |
| 77 | 3.5 | Detailschnitt | 10d | 2008-07-25 | 2008-08-08 | 76 | 0d | Klara Hektor; Richard Lund; Lisa Germer; Kim Schmitz; Labor | 400h | 8,310 |
| 78 | 3.6 | Formelle Abnahmevorführung | 1d | 2008-08-08 | 2008-08-11 | 77 | 0d | Klara Hektor; Michael Braun; Mark Müller [50%]; Stefan Meier [50%] | 24h | 342.5 |
| 79 | 3.7 | Text aufnehmen | 13.33d | 2008-08-11 | 2008-08-29 | 78 | 0d | David Kampmann [67.5%]; Michael Patten [67.5%]; Stefan Meier [67.5%] | 216h | 3,870 |
| 80 | 3.8 | Vor- und Abspann fertig stellen | 1w | 2008-08-29 | 2008-09-05 | 79 | 0d | Michael Braun; Michael Patten; Labor | 120h | 2,225 |
| 81 | 3.9 | Soundtrack fertig stellen | 16d | 2008-09-05 | 2008-09-29 | 80 | 0d | Michael Patten | 128h | 3,200 |
| 82 | 3.10 | Negativ ziehen | 3.25d | 2008-09-29 | 2008-10-02 | 81 | 0d | Florian Voss | 26h | 572 |
| 83 | 3.11 | Synchronisationsmaster auf Audiokassette speichern | 12d | 2008-10-02 | 2008-10-20 | 82 | 0d | Dora Hermann [50%] | 48h | 624 |
| 84 | 3.12 | Film- und Audiomaster archivieren | 1d | 2008-10-20 | 2008-10-21 | 83 | 0d | Dora Hermann [50%]; Labor; Daniel Penn | 20h | 327 |
| 85 | 3.13 | Fertige Filme an Vertrieb ausliefern | 1d | 2008-10-21 | 2008-10-22 | 84 | 0d | Michael Patten | 8h | 200 |
