# Kurzfilmprojekt 9a

Schedule from MS Project, 2008-01-07 to 2008-10-27, costs in €.

## Calendars

- Standard: Mon-Fri 08:00-12:00, 13:00-17:00; Sat-Sun off.
- Nachtaufnahmen: Mon-Fri 17:00-23:00; Sat-Sun off.

## Resources

| Resource | Group | Unit | Rate |
| --- | --- | --- | --- |
| Stefan Meier |  |  | 19.37 |
| Klara Hektor |  |  | 15.5 |
| Jonathan Perrera |  |  | 22 |
| Kim Schmitz |  |  | 24 |
| Michael Braun |  |  | 5.62 |
| Jan Miskowski |  |  | 18.75 |
| Max Meier |  |  | 18 |
| Dora Hermann |  |  | 13 |
| Erik Lang |  |  | 15 |
| Elektriker |  |  | 22 |
| Paul Born |  |  | 9.38 |
| Josef Mattes |  |  | 9.38 |
| Susanne Brenner |  |  | 9.38 |
| Frank Lee |  |  | 14 |
| Kerstin Heller |  |  | 9.4 |
| Thomas Bremer |  |  | 14 |
| 16-mm-Kamera |  |  | 6.25 |
| 500-Watt-Lampe |  |  | 2.5 |
| Joschi Rander |  |  | 12 |
| Melani Heuer |  |  | 17.5 |
| Tim Mahler |  |  | 14 |
| Kamerawagen |  |  | 50 |
| Erik Müller |  |  | 6.25 |
| Peter Henze |  |  | 9.38 |
| Anne L. Pape |  |  | 9.38 |
| Dolly |  |  | 9.38 |
| David Kampmann |  |  | 9.38 |
| Kran |  |  | 18.75 |
| Daniel Penn |  |  | 9.38 |
| Labor |  |  | 25 |
| Florian Voss |  |  | 22 |
| Michael Patten |  |  | 25 |
| Lisa Germer |  |  | 23.75 |
| Richard Lund |  |  | 15.62 |
| Mark Müller |  |  | 24 |
| 16-mm-Film | Film und Labor | 100 Feet | 25 |

## Schedule

| ID | WBS | Task | Type | Duration | Start | Finish | Predecessors | Baseline start | Baseline finish | Baseline duration | Total slack | Free slack | Constraint | Deadline | Resources | Work | Cost | Baseline cost |
| --- | --- | --- | --- | --- | --- | --- | --- | --- | --- | --- | --- | --- | --- | --- | --- | --- | --- | --- |
| 1 | 1 | **Produktionsvorbereitung** |  | 57.5d | 2008-01-07 | 2008-03-26 |  | 2008-01-07 | 2008-03-26 | 57.5d | 0.1d | 0d |  |  |  | 1238h | 23,820 | 23,820 |
| 2 | 1.1 | Drehbuch überarbeiten |  | 1w | 2008-01-07 | 2008-01-11 |  | 2008-01-07 | 2008-01-11 | 1w | 0.1d | 0d |  |  | Stefan Meier [50%]; Klara Hektor | 48h | 821.5 | 821.5 |
| 3 | 1.2 | Drehbuch in Teilaufgaben zerlegen |  | 1w | 2008-01-14 | 2008-01-18 | 2 | 2008-01-14 | 2008-01-18 | 1w | 0.1d | 0d |  |  | Stefan Meier; Jonathan Perrera | 80h | 1,655 | 1,655 |
| 4 | 1.3 | Produktionsablauf festlegen |  | 1mo | 2008-01-21 | 2008-02-19 | 3 | 2008-01-21 | 2008-02-19 | 1mo | 0.1d | 0d |  |  | Stefan Meier; Kim Schmitz; Jonathan Perrera | 480h | 10,460 | 10,460 |
| 5 | 1.4 | Drehorte erkunden |  | 2w | 2008-02-20 | 2008-03-04 | 4 | 2008-02-20 | 2008-03-04 | 2w | 0.1d | 0d |  |  | Michael Braun; Jan Miskowski; Max Meier | 240h | 3,390 | 3,390 |
| 6 | 1.5 | Drehorte auswählen |  | 1w | 2008-03-05 | 2008-03-11 | 5 | 2008-03-05 | 2008-03-11 | 1w | 0.1d | 0d |  |  | Stefan Meier; Klara Hektor; Max Meier | 120h | 2,115 | 2,115 |
| 7 | 1.6 | Vorsprechen abhalten |  | 1w | 2008-03-12 | 2008-03-18 | 6 | 2008-03-12 | 2008-03-18 | 1w | 0.1d | 0d |  |  | Klara Hektor; Stefan Meier; Dora Hermann [50%] | 100h | 1,655 | 1,655 |
| 8 | 1.7 | Dreherlaubnis beschaffen |  | 1w | 2008-03-19 | 2008-03-25 | 7 | 2008-03-19 | 2008-03-25 | 1w | 0.1d | 0d |  |  | Kim Schmitz | 40h | 1,460 | 1,460 |
| 9 | 1.8 | Kameraausrüstung reservieren |  | 3d | 2008-03-21 | 2008-03-26 | 8FS-5% | 2008-03-21 | 2008-03-26 | 3d | 0.1d | 0d |  |  | Jan Miskowski; Erik Lang | 48h | 810 | 810 |
| 10 | 1.9 | Tonausrüstung reservieren |  | 3d | 2008-03-21 | 2008-03-26 | 9SS | 2008-03-21 | 2008-03-26 | 3d | 0.1d | 0d |  |  | Erik Lang | 24h | 360 | 360 |
| 11 | 1.10 | Produktionsvorbereitung abschließen | milestone | 0d | 2008-03-26 | 2008-03-26 | 10 | 2008-03-26 | 2008-03-26 | 0d | 0.1d |  |  | 2008-03-28 |  |  |  |  |
| 12 | 1.11 | **Terminplanungsmeeting** |  | 45.25d | 2008-01-14 | 2008-03-17 |  | 2008-01-14 | 2008-03-17 | 45.25d | 7.35d |  |  |  |  | 58h | 1,093.5 | 1,093.5 |
| 13 | 1.11.1 | Terminplanungsmeeting 1 |  | 2h | 2008-01-14 | 2008-01-14 |  | 2008-01-14 | 2008-01-14 | 2h | 52.35d |  | start no earlier than 2008-01-14 |  | Klara Hektor; Jonathan Perrera; Stefan Meier | 6h | 113.75 | 113.75 |
| 14 | 1.11.2 | Terminplanungsmeeting 2 |  | 2h | 2008-01-21 | 2008-01-21 |  | 2008-01-21 | 2008-01-21 | 2h | 47.35d |  | start no earlier than 2008-01-21 |  | Klara Hektor; Jonathan Perrera; Stefan Meier | 4h | 69.75 | 69.75 |
| 15 | 1.11.3 | Terminplanungsmeeting 3 |  | 2h | 2008-01-28 | 2008-01-28 |  | 2008-01-28 | 2008-01-28 | 2h | 42.35d |  | start no earlier than 2008-01-28 |  | Klara Hektor; Jonathan Perrera; Stefan Meier | 6h | 113.75 | 113.75 |
| 16 | 1.11.4 | Terminplanungsmeeting 4 |  | 2h | 2008-02-04 | 2008-02-04 |  | 2008-02-04 | 2008-02-04 | 2h | 37.35d |  | start no earlier than 2008-02-04 |  | Klara Hektor; Jonathan Perrera; Stefan Meier | 6h | 113.75 | 113.75 |
| 17 | 1.11.5 | Terminplanungsmeeting 5 |  | 2h | 2008-02-11 | 2008-02-11 |  | 2008-02-11 | 2008-02-11 | 2h | 32.35d |  | start no earlier than 2008-02-11 |  | Klara Hektor; Jonathan Perrera; Stefan Meier | 6h | 113.75 | 113.75 |
| 18 | 1.11.6 | Terminplanungsmeeting 6 |  | 2h | 2008-02-18 | 2008-02-18 |  | 2008-02-18 | 2008-02-18 | 2h | 27.35d |  | start no earlier than 2008-02-18 |  | Klara Hektor; Jonathan Perrera; Stefan Meier | 6h | 113.75 | 113.75 |
| 19 | 1.11.7 | Terminplanungsmeeting 7 |  | 2h | 2008-02-25 | 2008-02-25 |  | 2008-02-25 | 2008-02-25 | 2h | 22.35d |  | start no earlier than 2008-02-25 |  | Klara Hektor; Jonathan Perrera; Stefan Meier | 6h | 113.75 | 113.75 |
| 20 | 1.11.8 | Terminplanungsmeeting 8 |  | 2h | 2008-03-03 | 2008-03-03 |  | 2008-03-03 | 2008-03-03 | 2h | 17.35d |  | start no earlier than 2008-03-03 |  | Klara Hektor; Jonathan Perrera; Stefan Meier | 6h | 113.75 | 113.75 |
| 21 | 1.11.9 | Terminplanungsmeeting 9 |  | 2h | 2008-03-10 | 2008-03-10 |  | 2008-03-10 | 2008-03-10 | 2h | 12.35d |  | start no earlier than 2008-03-10 |  | Klara Hektor; Jonathan Perrera; Stefan Meier | 6h | 113.75 | 113.75 |
| 22 | 1.11.10 | Terminplanungsmeeting 10 |  | 2h | 2008-03-17 | 2008-03-17 |  | 2008-03-17 | 2008-03-17 | 2h | 7.35d |  | start no earlier than 2008-03-17 |  | Klara Hektor; Jonathan Perrera; Stefan Meier | 6h | 113.75 | 113.75 |
| 23 | 2 | **Produktion** |  | 51.82d | 2008-03-26 | 2008-06-06 | 1 | 2008-03-26 | 2008-06-06 | 51.82d | 0d |  |  |  |  | 2231h | 27,183.77 | 27,183.77 |
| 24 | 2.1 | **Szene 7** |  | 5.4d | 2008-03-26 | 2008-04-02 |  | 2008-03-26 | 2008-04-02 | 5.4d | 0.1d | 0d |  |  |  | 228h | 2,901.5 | 2,901.5 |
| 25 | 2.1.1 | Szene 7 einrichten |  | 1.2d | 2008-03-26 | 2008-03-27 |  | 2008-03-26 | 2008-03-27 | 1.2d | 0.1d | 0d |  |  | Michael Braun; Max Meier; Elektriker [50%] | 24h | 332.4 | 332.4 |
| 26 | 2.1.2 | Szene 7 proben |  | 8h | 2008-03-27 | 2008-03-28 | 25 | 2008-03-27 | 2008-03-28 | 8h | 0.1d | 0d |  |  | Stefan Meier; Michael Braun; Paul Born [50%]; Josef Mattes; Susanne Brenner; Jan Miskowski | 44h | 537.5 | 537.5 |
| 27 | 2.1.3 | Szene 7 drehen |  | 8h | 2008-03-28 | 2008-03-31 | 26 | 2008-03-28 | 2008-03-31 | 8h | 0.1d | 0d |  |  | Stefan Meier; Michael Braun; Josef Mattes; Susanne Brenner; Frank Lee; Kerstin Heller; Thomas Bremer; 16-mm-Kamera [300%]; 500-Watt-Lampe [200%]; Joschi Rander; Melani Heuer; Tim Mahler; Jan Miskowski; Kamerawagen | 136h | 1,699.2 | 1,699.2 |
| 28 | 2.1.4 | Szene 7 Ergebnisse prüfen |  | 1.2d | 2008-03-31 | 2008-04-01 | 27 | 2008-03-31 | 2008-04-01 | 1.2d | 0.1d | 0d |  |  | Michael Braun; Max Meier; Elektriker [50%] | 24h | 332.4 | 332.4 |
| 29 | 2.1.5 | Szene 7 Tagesproduktion weiterverarbeiten |  | 1d | 2008-04-01 | 2008-04-02 | 28 | 2008-04-01 | 2008-04-02 | 1d | 0.1d |  |  |  |  |  |  |  |

| ID | WBS | Task | Duration | Start | Finish | Predecessors | Baseline start | Baseline finish | Baseline duration | Total slack | Free slack | Constraint | Calendar | Resources | Work | Cost | Baseline cost |
| --- | --- | --- | --- | --- | --- | --- | --- | --- | --- | --- | --- | --- | --- | --- | --- | --- | --- |
| 30 | 2.2 | **Szene 3** | 4d | 2008-04-02 | 2008-04-08 | 24 | 2008-04-02 | 2008-04-08 | 4d | 0.1d | 0d |  |  |  | 268h | 3,238.2 | 3,238.2 |
| 31 | 2.2.1 | Szene 3 einrichten | 1d | 2008-04-02 | 2008-04-03 |  | 2008-04-02 | 2008-04-03 | 1d | 0.1d | 0d | start no earlier than 2008-03-31 |  | Michael Braun; Max Meier; Elektriker | 24h | 365 | 365 |
| 32 | 2.2.2 | Szene 3 proben | 1d | 2008-04-03 | 2008-04-04 | 31 | 2008-04-03 | 2008-04-04 | 1d | 0.1d | 0d |  |  | Stefan Meier; Michael Braun; Erik Müller; Peter Henze; Anne L. Pape; Josef Mattes; Jan Miskowski | 56h | 625 | 625 |
| 33 | 2.2.3 | Szene 3 drehen | 8h | 2008-04-04 | 2008-04-07 | 32 | 2008-04-04 | 2008-04-07 | 8h | 0.1d | 0d |  |  | Stefan Meier; Michael Braun; Erik Müller; Peter Henze; Anne L. Pape; Josef Mattes; Tim Mahler; Melani Heuer; Dora Hermann [50%]; Kerstin Heller; 16-mm-Kamera [200%]; 500-Watt-Lampe [400%]; Dolly; Frank Lee; Jan Miskowski; Thomas Bremer; Kamerawagen | 164h | 1,883.2 | 1,883.2 |
| 34 | 2.2.4 | Szene 3 Ergebnisse prüfen | 1d | 2008-04-07 | 2008-04-08 | 33 | 2008-04-07 | 2008-04-08 | 1d | 0.1d |  |  |  | Michael Braun; Max Meier; Elektriker | 24h | 365 | 365 |
| 35 | 2.2.5 | Szene 3 Tagesproduktion weiterverarbeiten | 1d | 2008-04-07 | 2008-04-08 | 33 | 2008-04-07 | 2008-04-08 | 1d | 0.1d |  |  |  |  |  |  |  |
| 36 | 2.3 | **Szene 1** | 6d | 2008-04-08 | 2008-04-16 | 30 | 2008-04-08 | 2008-04-16 | 6d | 0.1d | 0d |  |  |  | 324h | 4,587.2 | 4,587.2 |
| 37 | 2.3.1 | Szene 1 einrichten | 3d | 2008-04-08 | 2008-04-11 |  | 2008-04-08 | 2008-04-11 | 3d | 0.1d | 0d |  |  | Michael Braun; Max Meier; Elektriker [200%] | 96h | 1,623 | 1,623 |
| 38 | 2.3.2 | Szene 1 proben | 1d | 2008-04-11 | 2008-04-14 | 37 | 2008-04-11 | 2008-04-14 | 1d | 0.1d | 0d |  |  | Stefan Meier; Michael Braun; Paul Born [50%]; David Kampmann; Erik Müller; Susanne Brenner; Jan Miskowski | 52h | 587.5 | 587.5 |
| 39 | 2.3.3 | Szene 1 drehen | 8h | 2008-04-14 | 2008-04-15 | 38 | 2008-04-14 | 2008-04-15 | 8h | 0.1d | 0d |  |  | Stefan Meier; Michael Braun; Paul Born [50%]; David Kampmann; Erik Müller; Susanne Brenner; Tim Mahler; Frank Lee; Melani Heuer; Dora Hermann [50%]; Kerstin Heller; Thomas Bremer; 16-mm-Kamera [300%]; 500-Watt-Lampe; Jan Miskowski; Dolly; Kamerawagen | 144h | 1,835.7 | 1,835.7 |
| 40 | 2.3.4 | Szene 1 Ergebnisse prüfen | 1d | 2008-04-15 | 2008-04-16 | 39 | 2008-04-15 | 2008-04-16 | 1d | 0.1d |  |  |  | Michael Braun; Max Meier; Elektriker [200%] | 32h | 541 | 541 |
| 41 | 2.3.5 | Szene 1 Tagesproduktion weiterverarbeiten | 1d | 2008-04-15 | 2008-04-16 | 39 | 2008-04-15 | 2008-04-16 | 1d | 0.1d |  |  |  |  |  |  |  |
| 42 | 2.4 | **Szene 2** | 3.6d | 2008-04-16 | 2008-04-22 | 36 | 2008-04-16 | 2008-04-22 | 3.6d | 0d |  |  |  |  | 138h | 1,906.1 | 1,906.1 |
| 43 | 2.4.1 | Szene 2 einrichten | 1d | 2008-04-16 | 2008-04-17 |  | 2008-04-16 | 2008-04-17 | 1d | 0.1d | 0d |  |  | Michael Braun; Max Meier; Elektriker | 24h | 365 | 365 |
| 44 | 2.4.2 | Szene 2 proben | 8h | 2008-04-17 | 2008-04-18 | 43 | 2008-04-17 | 2008-04-18 | 8h | 0.1d |  |  |  | Stefan Meier; Dora Hermann [50%]; David Kampmann; Anne L. Pape; Jan Miskowski | 36h | 507 | 507 |
| 45 | 2.4.3 | Szene 2 drehen | 4h | 2008-04-18 | 2008-04-18 | 44 | 2008-04-18 | 2008-04-18 | 4h | 0.25d | 0d |  | Nachtaufnahmen | Stefan Meier; Dora Hermann [50%]; Anne L. Pape; Tim Mahler; Frank Lee; Kerstin Heller; Thomas Bremer; 16-mm-Kamera [200%]; 500-Watt-Lampe [300%]; Jan Miskowski; David Kampmann; Kamerawagen; Kran; Dolly | 66h | 851.6 | 851.6 |
| 46 | 2.4.4 | Szene 2 Ergebnisse prüfen | 0.5d | 2008-04-21 | 2008-04-21 | 45 | 2008-04-21 | 2008-04-21 | 0.5d | 0d |  |  |  | Michael Braun; Max Meier; Elektriker | 12h | 182.5 | 182.5 |
| 47 | 2.4.5 | Szene 2 Tagesproduktion weiterverarbeiten | 1d | 2008-04-21 | 2008-04-22 | 46 | 2008-04-21 | 2008-04-22 | 1d | 0d |  |  |  |  |  |  |  |
| 48 | 2.5 | **Szene 5** | 5.5d | 2008-04-22 | 2008-04-29 | 42 | 2008-04-22 | 2008-04-29 | 5.5d | 0d |  |  |  |  | 280h | 3,354.7 | 3,354.7 |
| 49 | 2.5.1 | Szene 5 einrichten | 2.5d | 2008-04-22 | 2008-04-24 |  | 2008-04-22 | 2008-04-24 | 2.5d | 0d |  |  |  | Michael Braun; Max Meier | 40h | 472.5 | 472.5 |
| 50 | 2.5.2 | Szene 5 proben | 1d | 2008-04-25 | 2008-04-25 | 49 | 2008-04-25 | 2008-04-25 | 1d | 0d |  |  |  | Stefan Meier; Michael Braun; Erik Müller; David Kampmann; Susanne Brenner; Daniel Penn; Anne L. Pape; Jan Miskowski [50%] | 60h | 625 | 625 |
| 51 | 2.5.3 | Szene 5 drehen | 8h | 2008-04-28 | 2008-04-28 | 50 | 2008-04-28 | 2008-04-28 | 8h | 0d |  |  |  | Stefan Meier; Michael Braun; Erik Müller; David Kampmann; Susanne Brenner; Daniel Penn; Anne L. Pape; Tim Mahler; Frank Lee; Melani Heuer; Dora Hermann [50%]; Kerstin Heller; Thomas Bremer; 16-mm-Kamera [200%]; 500-Watt-Lampe [200%]; Kran; Jan Miskowski; Kamerawagen; Dolly | 164h | 2,068.2 | 2,068.2 |
| 52 | 2.5.4 | Szene 5 Ergebnisse prüfen | 1d | 2008-04-29 | 2008-04-29 | 51 | 2008-04-29 | 2008-04-29 | 1d | 0d |  |  |  | Michael Braun; Max Meier | 16h | 189 | 189 |
| 53 | 2.5.5 | Szene 5 Tagesproduktion weiterverarbeiten | 1d | 2008-04-29 | 2008-04-29 | 51 | 2008-04-29 | 2008-04-29 | 1d | 0d |  |  |  |  |  |  |  |

| ID | WBS | Task | Duration | Start | Finish | Predecessors | Baseline start | Baseline finish | Baseline duration | Total slack | Resources | Work | Cost | Baseline cost |
| --- | --- | --- | --- | --- | --- | --- | --- | --- | --- | --- | --- | --- | --- | --- |
| 54 | 2.6 | **Szene 6** | 13.57d | 2008-04-30 | 2008-05-19 | 48 | 2008-04-30 | 2008-05-19 | 13.57d | 0d |  | 556h | 5,919.07 | 5,919.07 |
| 55 | 2.6.1 | Szene 6 einrichten | 6d | 2008-04-30 | 2008-05-07 |  | 2008-04-30 | 2008-05-07 | 6d | 0d | Michael Braun; Max Meier | 96h | 1,134 | 1,134 |
| 56 | 2.6.2 | Szene 6 proben | 2d | 2008-05-08 | 2008-05-09 | 55 | 2008-05-08 | 2008-05-09 | 2d | 0d | Stefan Meier; Michael Braun; Dora Hermann [50%]; Paul Born [50%]; David Kampmann; Susanne Brenner; Anne L. Pape; Peter Henze; Daniel Penn; Jan Miskowski [50%] | 136h | 1,479 | 1,479 |
| 57 | 2.6.3 | Szene 6 drehen | 12.54h | 2008-05-12 | 2008-05-13 | 56 | 2008-05-12 | 2008-05-13 | 12.54h | 0d | Stefan Meier; Michael Braun; Dora Hermann [50%]; Paul Born [50%]; David Kampmann; Susanne Brenner; Anne L. Pape; Peter Henze; Daniel Penn; Frank Lee; Melani Heuer; Kerstin Heller; Thomas Bremer; 16-mm-Kamera [300%]; 500-Watt-Lampe [300%]; Dolly; Kran; Joschi Rander; Tim Mahler | 276h | 2,739.07 | 2,739.07 |
| 58 | 2.6.4 | Szene 6 Ergebnisse prüfen | 3d | 2008-05-13 | 2008-05-16 | 57 | 2008-05-13 | 2008-05-16 | 3d | 0d | Michael Braun; Max Meier | 48h | 567 | 567 |
| 59 | 2.6.5 | Szene 6 Tagesproduktion weiterverarbeiten | 1d | 2008-05-16 | 2008-05-19 | 58 | 2008-05-16 | 2008-05-19 | 1d | 0d |  |  |  |  |
| 60 | 2.7 | **Szene 8** | 9d | 2008-05-19 | 2008-05-30 | 54 | 2008-05-19 | 2008-05-30 | 9d | 0d |  | 346h | 4,122.45 | 4,122.45 |
| 61 | 2.7.1 | Szene 8 einrichten | 3d | 2008-05-19 | 2008-05-22 |  | 2008-05-19 | 2008-05-22 | 3d | 0d | Michael Braun; Max Meier | 48h | 567 | 567 |
| 62 | 2.7.2 | Szene 8 proben | 2.5d | 2008-05-22 | 2008-05-27 | 61 | 2008-05-22 | 2008-05-27 | 2.5d | 0d | Stefan Meier; Michael Braun; Dora Hermann [50%]; Paul Born [50%]; David Kampmann; Susanne Brenner; Erik Müller; Jan Miskowski [50%] | 130h | 1,411.25 | 1,411.25 |
| 63 | 2.7.3 | Szene 8 drehen | 8h | 2008-05-27 | 2008-05-28 | 62 | 2008-05-27 | 2008-05-28 | 8h | 0d | Stefan Meier; Michael Braun; Dora Hermann [50%]; Paul Born [50%]; David Kampmann; Susanne Brenner; Erik Müller; Tim Mahler; Frank Lee; Melani Heuer; Kerstin Heller; Thomas Bremer; 16-mm-Kamera [200%]; 500-Watt-Lampe; Dolly [200%]; Kamerawagen; Kran | 144h | 1,860.7 | 1,860.7 |
| 64 | 2.7.4 | Szene 8 Ergebnisse prüfen | 1.5d | 2008-05-28 | 2008-05-29 | 63 | 2008-05-28 | 2008-05-29 | 1.5d | 0d | Michael Braun; Max Meier | 24h | 283.5 | 283.5 |
| 65 | 2.7.5 | Szene 8 Tagesproduktion weiterverarbeiten | 1d | 2008-05-29 | 2008-05-30 | 64 | 2008-05-29 | 2008-05-30 | 1d | 0d |  |  |  |  |
| 66 | 2.8 | **Szene 4** | 4.75d | 2008-05-30 | 2008-06-06 | 60 | 2008-05-30 | 2008-06-06 | 4.75d | 0d |  | 91h | 1,154.55 | 1,154.55 |
| 67 | 2.8.1 | Szene 4 einrichten | 1.5d | 2008-05-30 | 2008-06-03 |  | 2008-05-30 | 2008-06-03 | 1.5d | 0d | Michael Braun; Max Meier | 24h | 283.5 | 283.5 |
| 68 | 2.8.2 | Szene 4 proben | 4h | 2008-06-03 | 2008-06-03 | 67 | 2008-06-03 | 2008-06-03 | 4h | 0d | Stefan Meier; Dora Hermann [50%]; Anne L. Pape; Josef Mattes; Jan Miskowski [50%] | 16h | 216 | 216 |
| 69 | 2.8.3 | Szene 4 drehen | 2h | 2008-06-03 | 2008-06-03 | 68 | 2008-06-03 | 2008-06-03 | 2h | 0d | Stefan Meier; Dora Hermann [50%]; Anne L. Pape; Josef Mattes; Frank Lee; Melani Heuer; Kerstin Heller; 16-mm-Kamera [200%]; 500-Watt-Lampe [200%]; Jan Miskowski; Thomas Bremer; Kamerawagen | 27h | 371.55 | 371.55 |
| 70 | 2.8.4 | Szene 4 Ergebnisse prüfen | 1.5d | 2008-06-03 | 2008-06-05 | 69 | 2008-06-03 | 2008-06-05 | 1.5d | 0d | Michael Braun; Max Meier | 24h | 283.5 | 283.5 |
| 71 | 2.8.5 | Szene 4 Tagesproduktion weiterverarbeiten | 1d | 2008-06-05 | 2008-06-06 | 70 | 2008-06-05 | 2008-06-06 | 1d | 0d |  |  |  |  |
| 72 | 3 | **Produktionsnachbereitung** | 101.35d | 2008-06-06 | 2008-10-27 | 23 | 2008-06-06 | 2008-10-27 | 101.35d | 0d |  | 1718h | 33,856.7 | 33,856.7 |
| 73 | 3.1 | Filmmaterial sichten | 8.5d | 2008-06-06 | 2008-06-18 |  | 2008-06-06 | 2008-06-18 | 8.5d | 0d | Labor; Florian Voss | 136h | 3,196 | 3,196 |
| 74 | 3.2 | Sprechtext grob festlegen | 12d | 2008-06-18 | 2008-07-04 | 73 | 2008-06-18 | 2008-07-04 | 12d | 0d | David Kampmann; Michael Patten | 192h | 3,300 | 3,300 |
| 75 | 3.3 | Filmsequenzen schriftlich bearbeiten | 10d | 2008-07-04 | 2008-07-18 | 74 | 2008-07-04 | 2008-07-18 | 10d | 0d | Klara Hektor; Kim Schmitz; Lisa Germer; Richard Lund | 320h | 6,310 | 6,310 |
| 76 | 3.4 | Grobschnitt | 5d | 2008-07-18 | 2008-07-25 | 75 | 2008-07-18 | 2008-07-25 | 5d | 0d | Klara Hektor; Richard Lund | 80h | 1,245 | 1,245 |
| 77 | 3.5 | Detailschnitt | 10d | 2008-07-25 | 2008-08-08 | 76 | 2008-07-25 | 2008-08-08 | 10d | 0d | Klara Hektor; Richard Lund; Lisa Germer; Kim Schmitz; Labor | 400h | 8,310 | 8,310 |
| 78 | 3.6 | Formelle Abnahmevorführung | 1d | 2008-08-08 | 2008-08-11 | 77 | 2008-08-08 | 2008-08-11 | 1d | 0d | Klara Hektor; Michael Braun; Mark Müller [50%]; Stefan Meier [50%] | 24h | 342.5 | 342.5 |
| 79 | 3.7 | Text aufnehmen | 15d | 2008-08-11 | 2008-09-01 | 78 | 2008-08-11 | 2008-09-01 | 15d | 0d | David Kampmann; Michael Patten; Stefan Meier | 216h | 3,870 | 3,870 |
| 80 | 3.8 | Vor- und Abspann fertig stellen | 1w | 2008-09-01 | 2008-09-08 | 79 | 2008-09-01 | 2008-09-08 | 1w | 0d | Michael Braun; Michael Patten; Labor | 120h | 2,225 | 2,225 |
| 81 | 3.9 | Soundtrack fertig stellen | 16d | 2008-09-08 | 2008-09-30 | 80 | 2008-09-08 | 2008-09-30 | 16d | 0d | Michael Patten | 128h | 3,200 | 3,200 |
| 82 | 3.10 | Negativ ziehen | 3.25d | 2008-09-30 | 2008-10-06 | 81 | 2008-09-30 | 2008-10-06 | 3.25d | 0d | Florian Voss | 26h | 572 | 572 |
| 83 | 3.11 | Synchronisationsmaster auf Audiokassette speichern | 12d | 2008-10-06 | 2008-10-22 | 82 | 2008-10-06 | 2008-10-22 | 12d | 0d | Dora Hermann [50%] | 48h | 748.8 | 748.8 |
| 84 | 3.12 | Film- und Audiomaster archivieren | 2d | 2008-10-22 | 2008-10-24 | 83 | 2008-10-22 | 2008-10-24 | 2d | 0d | Dora Hermann [50%]; Labor; Daniel Penn | 20h | 337.4 | 337.4 |
| 85 | 3.13 | Fertige Filme an Vertrieb ausliefern | 1d | 2008-10-24 | 2008-10-27 | 84 | 2008-10-24 | 2008-10-27 | 1d | 0d | Michael Patten | 8h | 200 | 200 |
