# Kurzfilmprojekt

Schedule from MS Project, 2008-01-07 to 2008-11-10, costs in €, A marks actual dates.
Industriefilm GmbH

## Calendars

- Standard: Mon-Fri 08:00-12:00, 13:00-17:00; Sat-Sun off.
- Nachtaufnahmen: Mon-Fri 17:00-23:00; Sat-Sun off.

## Resources

| Resource | Group | Unit | Rate |
| --- | --- | --- | --- |
| Stefan Meier | Produktion |  | 19.37 |
| Klara Hektor | Produktion |  | 15.5 |
| Jonathan Perrera | Produktion |  | 22 |
| Kim Schmitz | Produktion |  | 24 |
| Michael Braun | Produktion |  | 5.62 |
| Jan Miskowski | Produktion |  | 18.75 |
| Max Meier | Produktion |  | 18 |
| Dora Hermann | Produktion |  | 13 |
| Erik Lang | Produktion |  | 15 |
| Elektriker | Crew |  | 22 |
| Paul Born | Crew |  | 9.38 |
| Josef Mattes | Crew |  | 9.38 |
| Susanne Brenner | Produktion |  | 9.38 |
| Frank Lee | Crew |  | 14 |
| Kerstin Heller | Schauspieler/in |  | 9.4 |
| Thomas Bremer | Ausrüstung |  | 14 |
| 16-mm-Kamera | Film und Labor |  | 6.25 |
| 500-Watt-Lampe | Ausrüstung |  | 2.5 |
| Joschi Rander | Produktion |  | 12 |
| Melani Heuer | Produktion |  | 17.5 |
| Tim Mahler | Produktion |  | 14 |
| Kamerawagen | Ausrüstung |  | 50 |
| Erik Müller | Schauspieler/in |  | 6.25 |
| Peter Henze | Crew |  | 9.38 |
| Anne L. Pape | Schauspieler/in |  | 9.38 |
| Dolly | Crew |  | 9.38 |
| David Kampmann | Schauspieler/in |  | 9.38 |
| Kran | Ausrüstung |  | 18.75 |
| Daniel Penn | Schauspieler/in |  | 9.38 |
| Labor | Film und Labor |  | 25 |
| Florian Voss | Produktion |  | 22 |
| Michael Patten | Produktion |  | 25 |
| Lisa Germer | Produktion |  | 23.75 |
| Richard Lund | Produktion |  | 15.62 |
| Mark Müller | Crew |  | 24 |
| 16-mm-Film | Ausrüstung | 100 Feet | 25 |

## Schedule

| ID | WBS | Task | Type | Duration | Start | Finish | Predecessors | Complete | Remaining | Baseline start | Baseline finish | Baseline duration | Total slack | Free slack | Constraint | Deadline | Resources | Work | Actual work | Cost | Baseline cost | Actual cost | Besetzung | Drehort |
| --- | --- | --- | --- | --- | --- | --- | --- | --- | --- | --- | --- | --- | --- | --- | --- | --- | --- | --- | --- | --- | --- | --- | --- | --- |
| 1 | 1 | **Produktionsvorbereitung** |  | 78d | 2008-01-07 A | 2008-04-23 |  | 99% | 0d | 2008-01-07 | 2008-03-26 | 57.5d | -12.75d | 0d |  |  |  | 1310h | 1310h | 25,134 | 23,820 | 25,134 |  |  |
| 2 | 1.1 | Drehbuch überarbeiten |  | 1w | 2008-01-07 A | 2008-01-11 A |  | 100% |  | 2008-01-07 | 2008-01-11 | 1w |  |  |  |  | Stefan Meier [50%]; Klara Hektor | 48h | 48h | 821.5 | 821.5 | 821.5 |  |  |
| 3 | 1.2 | Drehbuch in Teilaufgaben zerlegen |  | 1.05w | 2008-01-14 A | 2008-01-21 A | 2 | 100% |  | 2008-01-14 | 2008-01-18 | 1w |  |  |  |  | Stefan Meier; Jonathan Perrera | 80h | 80h | 1,655 | 1,655 | 1,655 |  |  |
| 4 | 1.3 | Produktionsablauf festlegen |  | 1.04mo | 2008-01-21 A | 2008-02-21 A | 3 | 100% |  | 2008-01-21 | 2008-02-19 | 1mo |  |  |  |  | Stefan Meier; Kim Schmitz; Jonathan Perrera | 480h | 480h | 10,460 | 10,460 | 10,460 |  |  |
| 5 | 1.4 | Produktionsablauf überwachen |  | 1.2w | 2008-02-21 A | 2008-02-29 A | 4 | 100% |  |  |  |  |  |  |  |  | Klara Hektor; Stefan Meier | 96h | 96h | 1,674 |  | 1,674 |  |  |
| 6 | 1.5 | Drehorte erkunden |  | 2w | 2008-02-29 A | 2008-03-14 A | 5 | 100% |  | 2008-02-20 | 2008-03-04 | 2w |  |  |  |  | Michael Braun; Jan Miskowski; Max Meier | 240h | 240h | 3,390 | 3,390 | 3,390 |  |  |
| 7 | 1.6 | Drehorte auswählen |  | 1.05w | 2008-03-14 A | 2008-03-21 A | 6 | 100% |  | 2008-03-05 | 2008-03-11 | 1w |  |  |  |  | Stefan Meier; Klara Hektor; Max Meier | 120h | 120h | 2,115 | 2,115 | 2,115 |  |  |
| 8 | 1.7 | Vorsprechen abhalten |  | 1.05w | 2008-03-21 A | 2008-03-28 A | 7 | 100% |  | 2008-03-12 | 2008-03-18 | 1w |  |  |  |  | Klara Hektor; Stefan Meier; Dora Hermann [50%] | 100h | 100h | 1,655 | 1,655 | 1,655 |  |  |
| 9 | 1.8 | Dreherlaubnis beschaffen |  | 1w | 2008-03-28 A | 2008-04-04 A | 8 | 100% |  | 2008-03-19 | 2008-03-25 | 1w |  |  |  |  | Kim Schmitz | 40h | 40h | 1,460 | 1,460 | 1,460 |  |  |
| 10 | 1.9 | Kameraausrüstung reservieren |  | 3d | 2008-04-02 A | 2008-04-07 A | 9FS-5% | 100% |  | 2008-03-21 | 2008-03-26 | 3d |  |  |  |  | Jan Miskowski; Erik Lang [50%] | 36h | 36h | 630 | 810 | 630 |  |  |
| 11 | 1.10 | Tonausrüstung reservieren |  | 3d | 2008-04-02 A | 2008-04-07 A | 10SS | 100% |  | 2008-03-21 | 2008-03-26 | 3d |  |  |  |  | Erik Lang [50%] | 12h | 12h | 180 | 360 | 180 |  |  |
| 12 | 1.11 | Produktionsvorbereitung abschließen | milestone | 0d | 2008-04-23 | 2008-04-23 | 11 |  |  | 2008-03-26 | 2008-03-26 | 0d | -18d | 0d | start no earlier than 2008-04-23 | 2008-03-28 |  |  |  |  |  |  |  |  |
| 13 | 1.12 | **Terminplanungsmeeting** |  | 45.25d | 2008-01-14 A | 2008-03-17 A |  | 100% |  | 2008-01-14 | 2008-03-17 | 45.25d |  |  |  |  |  | 58h | 58h | 1,093.5 | 1,093.5 | 1,093.5 |  |  |
| 14 | 1.12.1 | Terminplanungsmeeting 1 |  | 2h | 2008-01-14 A | 2008-01-14 A |  | 100% |  | 2008-01-14 | 2008-01-14 | 2h |  |  | start no earlier than 2008-01-14 |  | Klara Hektor; Jonathan Perrera; Stefan Meier | 6h | 6h | 113.75 | 113.75 | 113.75 |  |  |
| 15 | 1.12.2 | Terminplanungsmeeting 2 |  | 2h | 2008-01-21 A | 2008-01-21 A |  | 100% |  | 2008-01-21 | 2008-01-21 | 2h |  |  | start no earlier than 2008-01-21 |  | Klara Hektor; Jonathan Perrera; Stefan Meier | 4h | 4h | 69.75 | 69.75 | 69.75 |  |  |
| 16 | 1.12.3 | Terminplanungsmeeting 3 |  | 2h | 2008-01-28 A | 2008-01-28 A |  | 100% |  | 2008-01-28 | 2008-01-28 | 2h |  |  | start no earlier than 2008-01-28 |  | Klara Hektor; Jonathan Perrera; Stefan Meier | 6h | 6h | 113.75 | 113.75 | 113.75 |  |  |
| 17 | 1.12.4 | Terminplanungsmeeting 4 |  | 2h | 2008-02-04 A | 2008-02-04 A |  | 100% |  | 2008-02-04 | 2008-02-04 | 2h |  |  | start no earlier than 2008-02-04 |  | Klara Hektor; Jonathan Perrera; Stefan Meier | 6h | 6h | 113.75 | 113.75 | 113.75 |  |  |
| 18 | 1.12.5 | Terminplanungsmeeting 5 |  | 2h | 2008-02-11 A | 2008-02-11 A |  | 100% |  | 2008-02-11 | 2008-02-11 | 2h |  |  | start no earlier than 2008-02-11 |  | Klara Hektor; Jonathan Perrera; Stefan Meier | 6h | 6h | 113.75 | 113.75 | 113.75 |  |  |
| 19 | 1.12.6 | Terminplanungsmeeting 6 |  | 2h | 2008-02-18 A | 2008-02-18 A |  | 100% |  | 2008-02-18 | 2008-02-18 | 2h |  |  | start no earlier than 2008-02-18 |  | Klara Hektor; Jonathan Perrera; Stefan Meier | 6h | 6h | 113.75 | 113.75 | 113.75 |  |  |
| 20 | 1.12.7 | Terminplanungsmeeting 7 |  | 2h | 2008-02-25 A | 2008-02-25 A |  | 100% |  | 2008-02-25 | 2008-02-25 | 2h |  |  | start no earlier than 2008-02-25 |  | Klara Hektor; Jonathan Perrera; Stefan Meier | 6h | 6h | 113.75 | 113.75 | 113.75 |  |  |
| 21 | 1.12.8 | Terminplanungsmeeting 8 |  | 2h | 2008-03-03 A | 2008-03-03 A |  | 100% |  | 2008-03-03 | 2008-03-03 | 2h |  |  | start no earlier than 2008-03-03 |  | Klara Hektor; Jonathan Perrera; Stefan Meier | 6h | 6h | 113.75 | 113.75 | 113.75 |  |  |
| 22 | 1.12.9 | Terminplanungsmeeting 9 |  | 2h | 2008-03-10 A | 2008-03-10 A |  | 100% |  | 2008-03-10 | 2008-03-10 | 2h |  |  | start no earlier than 2008-03-10 |  | Klara Hektor; Jonathan Perrera; Stefan Meier | 6h | 6h | 113.75 | 113.75 | 113.75 |  |  |
| 23 | 1.12.10 | Terminplanungsmeeting 10 |  | 2h | 2008-03-17 A | 2008-03-17 A |  | 100% |  | 2008-03-17 | 2008-03-17 | 2h |  |  | start no earlier than 2008-03-17 |  | Klara Hektor; Jonathan Perrera; Stefan Meier | 6h | 6h | 113.75 | 113.75 | 113.75 |  |  |
| 24 | 2 | **Produktion** |  | 54.07d | 2008-04-07 A | 2008-06-20 | 1 | 33% | 36.18d | 2008-03-26 | 2008-06-06 | 51.82d | 0d |  |  |  |  | 2260h | 849h | 30,626.02 | 27,183.77 | 13,309.85 |  |  |
| 25 | 2.1 | **Szene 7** |  | 13.75d | 2008-04-07 A | 2008-04-24 A |  | 100% |  | 2008-03-26 | 2008-04-02 | 5.4d |  |  |  |  |  | 241h | 241h | 3,537.35 | 2,901.5 | 3,537.35 |  |  |
| 26 | 2.1.1 | Szene 7 einrichten |  | 1.95d | 2008-04-07 A | 2008-04-09 A |  | 100% |  | 2008-03-26 | 2008-03-27 | 1.2d |  |  |  |  | Michael Braun; Max Meier; Elektriker [50%] | 24h | 24h | 912 | 332.4 | 912 |  |  |
| 27 | 2.1.2 | Szene 7 proben |  | 12.4h | 2008-04-09 A | 2008-04-10 A | 26 | 100% |  | 2008-03-27 | 2008-03-28 | 8h |  |  |  |  | Stefan Meier; Michael Braun; Paul Born [46.9%]; Josef Mattes [133.3%]; Susanne Brenner; Jan Miskowski [116.7%] | 49h | 49h | 593.75 | 537.5 | 593.75 |  |  |
| 28 | 2.1.3 | Szene 7 drehen |  | 8h | 2008-04-10 A | 2008-04-11 A | 27 | 100% |  | 2008-03-28 | 2008-03-31 | 8h |  |  |  |  | Stefan Meier; Michael Braun; Josef Mattes; Susanne Brenner; Frank Lee; Kerstin Heller; Thomas Bremer; 16-mm-Kamera [300%]; 500-Watt-Lampe [200%]; Joschi Rander; Melani Heuer; Tim Mahler; Jan Miskowski; Kamerawagen | 136h | 136h | 1,699.2 | 1,699.2 | 1,699.2 | Richard, Verkäufer 1, Verkäufer 2 | Supermarkt |
| 29 | 2.1.4 | Szene 7 Ergebnisse prüfen |  | 1.2d | 2008-04-11 A | 2008-04-14 A | 28 | 100% |  | 2008-03-31 | 2008-04-01 | 1.2d |  |  |  |  | Michael Braun; Max Meier; Elektriker [50%] | 24h | 24h | 332.4 | 332.4 | 332.4 |  |  |
| 30 | 2.1.5 | Szene 7 Tagesproduktion weiterverarbeiten |  | 1d | 2008-04-24 A | 2008-04-24 A | 29 | 100% |  | 2008-04-01 | 2008-04-02 | 1d |  |  | start no earlier than 2008-04-23 |  |  | 8h | 8h |  |  |  |  |  |

| ID | WBS | Task | Duration | Start | Finish | Predecessors | Complete | Baseline start | Baseline finish | Baseline duration | Total slack | Free slack | Constraint | Calendar | Resources | Work | Actual work | Cost | Baseline cost | Actual cost | Besetzung | Drehort |
| --- | --- | --- | --- | --- | --- | --- | --- | --- | --- | --- | --- | --- | --- | --- | --- | --- | --- | --- | --- | --- | --- | --- |
| 31 | 2.2 | **Szene 3** | 4d | 2008-04-15 A | 2008-04-21 A | 25 | 100% | 2008-04-02 | 2008-04-08 | 4d |  |  |  |  |  | 276h | 276h | 3,679 | 3,238.2 | 3,679 |  |  |
| 32 | 2.2.1 | Szene 3 einrichten | 1d | 2008-04-15 A | 2008-04-16 A |  | 100% | 2008-04-02 | 2008-04-03 | 1d |  |  | start no earlier than 2008-03-31 |  | Michael Braun; Max Meier; Elektriker | 24h | 24h | 689 | 365 | 689 |  |  |
| 33 | 2.2.2 | Szene 3 proben | 1d | 2008-04-16 A | 2008-04-17 A | 32 | 100% | 2008-04-03 | 2008-04-04 | 1d |  |  |  |  | Stefan Meier; Michael Braun; Erik Müller; Peter Henze; Anne L. Pape; Josef Mattes; Jan Miskowski | 56h | 56h | 625 | 625 | 625 |  |  |
| 34 | 2.2.3 | Szene 3 drehen | 8h | 2008-04-17 A | 2008-04-18 A | 33 | 100% | 2008-04-04 | 2008-04-07 | 8h |  |  |  |  | Stefan Meier; Michael Braun; Erik Müller; Peter Henze; Anne L. Pape; Josef Mattes; Tim Mahler; Melani Heuer; Dora Hermann [50%]; Kerstin Heller; 16-mm-Kamera [200%]; 500-Watt-Lampe [400%]; Dolly; Frank Lee; Jan Miskowski; Thomas Bremer; Kamerawagen | 164h | 164h | 2,000 | 1,883.2 | 2,000 | Mann auf der Straße, Richard | Straßenecke |
| 35 | 2.2.4 | Szene 3 Ergebnisse prüfen | 1d | 2008-04-18 A | 2008-04-21 A | 34 | 100% | 2008-04-07 | 2008-04-08 | 1d |  |  |  |  | Michael Braun; Max Meier; Elektriker | 24h | 24h | 365 | 365 | 365 |  |  |
| 36 | 2.2.5 | Szene 3 Tagesproduktion weiterverarbeiten | 1d | 2008-04-18 A | 2008-04-21 A | 34 | 100% | 2008-04-07 | 2008-04-08 | 1d |  |  |  |  |  | 8h | 8h |  |  |  |  |  |
| 37 | 2.3 | **Szene 1** | 7d | 2008-04-21 A | 2008-04-30 A | 31 | 100% | 2008-04-08 | 2008-04-16 | 6d |  |  |  |  |  | 332h | 332h | 6,093.5 | 4,587.2 | 6,093.5 |  |  |
| 38 | 2.3.1 | Szene 1 einrichten | 3d | 2008-04-21 A | 2008-04-25 A |  | 100% | 2008-04-08 | 2008-04-11 | 3d |  |  |  |  | Michael Braun; Max Meier; Elektriker [200%] | 96h | 96h | 2,509 | 1,623 | 2,509 |  |  |
| 39 | 2.3.2 | Szene 1 proben | 1d | 2008-04-25 A | 2008-04-28 A | 38 | 100% | 2008-04-11 | 2008-04-14 | 1d |  |  |  |  | Stefan Meier; Michael Braun; Paul Born [50%]; David Kampmann; Erik Müller; Susanne Brenner; Jan Miskowski | 52h | 52h | 587.5 | 587.5 | 587.5 |  |  |
| 40 | 2.3.3 | Szene 1 drehen | 8h | 2008-04-28 A | 2008-04-29 A | 39 | 100% | 2008-04-14 | 2008-04-15 | 8h |  |  |  |  | Stefan Meier; Michael Braun; Paul Born [50%]; David Kampmann; Erik Müller; Susanne Brenner; Tim Mahler; Frank Lee; Melani Heuer; Dora Hermann [50%]; Kerstin Heller; Thomas Bremer; 16-mm-Kamera [300%]; 500-Watt-Lampe; Jan Miskowski; Dolly; Kamerawagen | 144h | 144h | 2,456 | 1,835.7 | 2,456 | Gerd, Mann auf der Straße, Verkäufer 1 | Straßenecke |
| 41 | 2.3.4 | Szene 1 Ergebnisse prüfen | 1d | 2008-04-29 A | 2008-04-30 A | 40 | 100% | 2008-04-15 | 2008-04-16 | 1d |  |  |  |  | Michael Braun; Max Meier; Elektriker [200%] | 32h | 32h | 541 | 541 | 541 |  |  |
| 42 | 2.3.5 | Szene 1 Tagesproduktion weiterverarbeiten | 1d | 2008-04-29 A | 2008-04-30 A | 40 | 100% | 2008-04-15 | 2008-04-16 | 1d |  |  |  |  |  | 8h | 8h |  |  |  |  |  |
| 43 | 2.4 | **Szene 2** | 3.55d | 2008-04-30 | 2008-05-06 | 37 |  | 2008-04-16 | 2008-04-22 | 3.6d | 0d |  |  |  |  | 138h |  | 2,086.1 | 1,906.1 |  |  |  |
| 44 | 2.4.1 | Szene 2 einrichten | 1d | 2008-04-30 | 2008-05-01 |  |  | 2008-04-16 | 2008-04-17 | 1d | 0.05d | 0d |  |  | Michael Braun; Max Meier; Elektriker | 24h |  | 545 | 365 |  |  |  |
| 45 | 2.4.2 | Szene 2 proben | 8h | 2008-05-01 | 2008-05-02 | 44 |  | 2008-04-17 | 2008-04-18 | 8h | 0.05d |  |  |  | Stefan Meier; Dora Hermann [50%]; David Kampmann; Anne L. Pape; Jan Miskowski | 36h |  | 507 | 507 |  |  |  |
| 46 | 2.4.3 | Szene 2 drehen | 4h | 2008-05-02 | 2008-05-02 | 45 |  | 2008-04-18 | 2008-04-18 | 4h | 0.25d | 0d |  | Nachtaufnahmen | Stefan Meier; Dora Hermann [50%]; Anne L. Pape; Tim Mahler; Frank Lee; Kerstin Heller; Thomas Bremer; 16-mm-Kamera [200%]; 500-Watt-Lampe [300%]; Jan Miskowski; David Kampmann; Kamerawagen; Kran; Dolly | 66h |  | 851.6 | 851.6 |  | Gerd, Susie | Susies Wohnzimmer |
| 47 | 2.4.4 | Szene 2 Ergebnisse prüfen | 0.5d | 2008-05-05 | 2008-05-05 | 46 |  | 2008-04-21 | 2008-04-21 | 0.5d | 0d |  |  |  | Michael Braun; Max Meier; Elektriker | 12h |  | 182.5 | 182.5 |  |  |  |
| 48 | 2.4.5 | Szene 2 Tagesproduktion weiterverarbeiten | 1d | 2008-05-05 | 2008-05-06 | 47 |  | 2008-04-21 | 2008-04-22 | 1d | 0d |  |  |  |  |  |  |  |  |  |  |  |
| 49 | 2.5 | **Szene 5** | 5.5d | 2008-05-06 | 2008-05-13 | 43 |  | 2008-04-22 | 2008-04-29 | 5.5d | 0d |  |  |  |  | 280h |  | 3,813 | 3,354.7 |  |  |  |
| 50 | 2.5.1 | Szene 5 einrichten | 2.5d | 2008-05-06 | 2008-05-08 |  |  | 2008-04-22 | 2008-04-24 | 2.5d | 0d |  |  |  | Michael Braun; Max Meier | 40h |  | 399 | 472.5 |  |  |  |
| 51 | 2.5.2 | Szene 5 proben | 1d | 2008-05-09 | 2008-05-09 | 50 |  | 2008-04-25 | 2008-04-25 | 1d | 0d |  |  |  | Stefan Meier; Michael Braun; Erik Müller; David Kampmann; Susanne Brenner; Daniel Penn; Anne L. Pape; Jan Miskowski [50%] | 60h |  | 625 | 625 |  |  |  |
| 52 | 2.5.3 | Szene 5 drehen | 8h | 2008-05-12 | 2008-05-12 | 51 |  | 2008-04-28 | 2008-04-28 | 8h | 0d |  |  |  | Stefan Meier; Michael Braun; Erik Müller; David Kampmann; Susanne Brenner; Daniel Penn; Anne L. Pape; Tim Mahler; Frank Lee; Melani Heuer; Dora Hermann [50%]; Kerstin Heller; Thomas Bremer; 16-mm-Kamera [200%]; 500-Watt-Lampe [200%]; Kran; Jan Miskowski; Kamerawagen; Dolly | 164h |  | 2,600 | 2,068.2 |  | Mann auf der Straße, Gerd, Alter Mann, Susie | Straßenecke |
| 53 | 2.5.4 | Szene 5 Ergebnisse prüfen | 1d | 2008-05-13 | 2008-05-13 | 52 |  | 2008-04-29 | 2008-04-29 | 1d | 0d |  |  |  | Michael Braun; Max Meier | 16h |  | 189 | 189 |  |  |  |
| 54 | 2.5.5 | Szene 5 Tagesproduktion weiterverarbeiten | 1d | 2008-05-13 | 2008-05-13 | 52 |  | 2008-04-29 | 2008-04-29 | 1d | 0d |  |  |  |  |  |  |  |  |  |  |  |

| ID | WBS | Task | Duration | Start | Finish | Predecessors | Baseline start | Baseline finish | Baseline duration | Total slack | Resources | Work | Cost | Baseline cost | Besetzung | Drehort |
| --- | --- | --- | --- | --- | --- | --- | --- | --- | --- | --- | --- | --- | --- | --- | --- | --- |
| 55 | 2.6 | **Szene 6** | 13.57d | 2008-05-14 | 2008-06-02 | 49 | 2008-04-30 | 2008-05-19 | 13.57d | 0d |  | 556h | 6,140.07 | 5,919.07 |  |  |
| 56 | 2.6.1 | Szene 6 einrichten | 6d | 2008-05-14 | 2008-05-21 |  | 2008-04-30 | 2008-05-07 | 6d | 0d | Michael Braun; Max Meier | 96h | 1,134 | 1,134 |  |  |
| 57 | 2.6.2 | Szene 6 proben | 2d | 2008-05-22 | 2008-05-23 | 56 | 2008-05-08 | 2008-05-09 | 2d | 0d | Stefan Meier; Michael Braun; Dora Hermann [50%]; Paul Born [50%]; David Kampmann; Susanne Brenner; Anne L. Pape; Peter Henze; Daniel Penn; Jan Miskowski [50%] | 136h | 1,700 | 1,479 |  |  |
| 58 | 2.6.3 | Szene 6 drehen | 12.54h | 2008-05-26 | 2008-05-27 | 57 | 2008-05-12 | 2008-05-13 | 12.54h | 0d | Stefan Meier; Michael Braun; Dora Hermann [50%]; Paul Born [50%]; David Kampmann; Susanne Brenner; Anne L. Pape; Peter Henze; Daniel Penn; Frank Lee; Melani Heuer; Kerstin Heller; Thomas Bremer; 16-mm-Kamera [300%]; 500-Watt-Lampe [300%]; Dolly; Kran; Joschi Rander; Tim Mahler | 276h | 2,739.07 | 2,739.07 | Gerd, Verkäufer 1, Susie, Mann auf der Straße | Supermarkt |
| 59 | 2.6.4 | Szene 6 Ergebnisse prüfen | 3d | 2008-05-27 | 2008-05-30 | 58 | 2008-05-13 | 2008-05-16 | 3d | 0d | Michael Braun; Max Meier | 48h | 567 | 567 |  |  |
| 60 | 2.6.5 | Szene 6 Tagesproduktion weiterverarbeiten | 1d | 2008-05-30 | 2008-06-02 | 59 | 2008-05-16 | 2008-05-19 | 1d | 0d |  |  |  |  |  |  |
| 61 | 2.7 | **Szene 8** | 9d | 2008-06-02 | 2008-06-13 | 55 | 2008-05-19 | 2008-05-30 | 9d | 0d |  | 346h | 4,122.45 | 4,122.45 |  |  |
| 62 | 2.7.1 | Szene 8 einrichten | 3d | 2008-06-02 | 2008-06-05 |  | 2008-05-19 | 2008-05-22 | 3d | 0d | Michael Braun; Max Meier | 48h | 567 | 567 |  |  |
| 63 | 2.7.2 | Szene 8 proben | 2.5d | 2008-06-05 | 2008-06-10 | 62 | 2008-05-22 | 2008-05-27 | 2.5d | 0d | Stefan Meier; Michael Braun; Dora Hermann [50%]; Paul Born [50%]; David Kampmann; Susanne Brenner; Erik Müller; Jan Miskowski [50%] | 130h | 1,411.25 | 1,411.25 |  |  |
| 64 | 2.7.3 | Szene 8 drehen | 8h | 2008-06-10 | 2008-06-11 | 63 | 2008-05-27 | 2008-05-28 | 8h | 0d | Stefan Meier; Michael Braun; Dora Hermann [50%]; Paul Born [50%]; David Kampmann; Susanne Brenner; Erik Müller; Tim Mahler; Frank Lee; Melani Heuer; Kerstin Heller; Thomas Bremer; 16-mm-Kamera [200%]; 500-Watt-Lampe; Dolly [200%]; Kamerawagen; Kran | 144h | 1,860.7 | 1,860.7 | Gerd, Verkäufer 1, Mann auf der Straße | Straßenecke |
| 65 | 2.7.4 | Szene 8 Ergebnisse prüfen | 1.5d | 2008-06-11 | 2008-06-12 | 64 | 2008-05-28 | 2008-05-29 | 1.5d | 0d | Michael Braun; Max Meier | 24h | 283.5 | 283.5 |  |  |
| 66 | 2.7.5 | Szene 8 Tagesproduktion weiterverarbeiten | 1d | 2008-06-12 | 2008-06-13 | 65 | 2008-05-29 | 2008-05-30 | 1d | 0d |  |  |  |  |  |  |
| 67 | 2.8 | **Szene 4** | 4.75d | 2008-06-13 | 2008-06-20 | 61 | 2008-05-30 | 2008-06-06 | 4.75d | 0d |  | 91h | 1,154.55 | 1,154.55 |  |  |
| 68 | 2.8.1 | Szene 4 einrichten | 1.5d | 2008-06-13 | 2008-06-17 |  | 2008-05-30 | 2008-06-03 | 1.5d | 0d | Michael Braun; Max Meier | 24h | 283.5 | 283.5 |  |  |
| 69 | 2.8.2 | Szene 4 proben | 4h | 2008-06-17 | 2008-06-17 | 68 | 2008-06-03 | 2008-06-03 | 4h | 0d | Stefan Meier; Dora Hermann [50%]; Anne L. Pape; Josef Mattes; Jan Miskowski [50%] | 16h | 216 | 216 |  |  |
| 70 | 2.8.3 | Szene 4 drehen | 2h | 2008-06-17 | 2008-06-17 | 69 | 2008-06-03 | 2008-06-03 | 2h | 0d | Stefan Meier; Dora Hermann [50%]; Anne L. Pape; Josef Mattes; Frank Lee; Melani Heuer; Kerstin Heller; 16-mm-Kamera [200%]; 500-Watt-Lampe [200%]; Jan Miskowski; Thomas Bremer; Kamerawagen | 27h | 371.55 | 371.55 | Susie, Richard | Aufzug |
| 71 | 2.8.4 | Szene 4 Ergebnisse prüfen | 1.5d | 2008-06-17 | 2008-06-19 | 70 | 2008-06-03 | 2008-06-05 | 1.5d | 0d | Michael Braun; Max Meier | 24h | 283.5 | 283.5 |  |  |
| 72 | 2.8.5 | Szene 4 Tagesproduktion weiterverarbeiten | 1d | 2008-06-19 | 2008-06-20 | 71 | 2008-06-05 | 2008-06-06 | 1d | 0d |  |  |  |  |  |  |
| 73 | 3 | **Produktionsnachbereitung** | 101.35d | 2008-06-20 | 2008-11-10 | 24 | 2008-06-06 | 2008-10-27 | 101.35d | 0d |  | 1718h | 33,856.7 | 33,856.7 |  |  |
| 74 | 3.1 | Filmmaterial sichten | 8.5d | 2008-06-20 | 2008-07-02 |  | 2008-06-06 | 2008-06-18 | 8.5d | 0d | Labor; Florian Voss | 136h | 3,196 | 3,196 |  |  |
| 75 | 3.2 | Sprechtext grob festlegen | 12d | 2008-07-02 | 2008-07-18 | 74 | 2008-06-18 | 2008-07-04 | 12d | 0d | David Kampmann; Michael Patten | 192h | 3,300 | 3,300 |  |  |
| 76 | 3.3 | Filmsequenzen schriftlich bearbeiten | 10d | 2008-07-18 | 2008-08-01 | 75 | 2008-07-04 | 2008-07-18 | 10d | 0d | Klara Hektor; Kim Schmitz; Lisa Germer; Richard Lund | 320h | 6,310 | 6,310 |  |  |
| 77 | 3.4 | Grobschnitt | 5d | 2008-08-01 | 2008-08-08 | 76 | 2008-07-18 | 2008-07-25 | 5d | 0d | Klara Hektor; Richard Lund | 80h | 1,245 | 1,245 |  |  |
| 78 | 3.5 | Detailschnitt | 10d | 2008-08-08 | 2008-08-22 | 77 | 2008-07-25 | 2008-08-08 | 10d | 0d | Klara Hektor; Richard Lund; Lisa Germer; Kim Schmitz; Labor | 400h | 8,310 | 8,310 |  |  |
| 79 | 3.6 | Formelle Abnahmevorführung | 1d | 2008-08-22 | 2008-08-25 | 78 | 2008-08-08 | 2008-08-11 | 1d | 0d | Klara Hektor; Michael Braun; Mark Müller [50%]; Stefan Meier [50%] | 24h | 342.5 | 342.5 |  |  |
| 80 | 3.7 | Text aufnehmen | 15d | 2008-08-25 | 2008-09-15 | 79 | 2008-08-11 | 2008-09-01 | 15d | 0d | David Kampmann; Michael Patten; Stefan Meier | 216h | 3,870 | 3,870 |  |  |
| 81 | 3.8 | Vor- und Abspann fertig stellen | 1w | 2008-09-15 | 2008-09-22 | 80 | 2008-09-01 | 2008-09-08 | 1w | 0d | Michael Braun; Michael Patten; Labor | 120h | 2,225 | 2,225 |  |  |
| 82 | 3.9 | Soundtrack fertig stellen | 16d | 2008-09-22 | 2008-10-14 | 81 | 2008-09-08 | 2008-09-30 | 16d | 0d | Michael Patten | 128h | 3,200 | 3,200 |  |  |
| 83 | 3.10 | Negativ ziehen | 3.25d | 2008-10-14 | 2008-10-20 | 82 | 2008-09-30 | 2008-10-06 | 3.25d | 0d | Florian Voss | 26h | 572 | 572 |  |  |
| 84 | 3.11 | Synchronisationsmaster auf Audiokassette speichern | 12d | 2008-10-20 | 2008-11-05 | 83 | 2008-10-06 | 2008-10-22 | 12d | 0d | Dora Hermann [50%] | 48h | 748.8 | 748.8 |  |  |
| 85 | 3.12 | Film- und Audiomaster archivieren | 2d | 2008-11-05 | 2008-11-07 | 84 | 2008-10-22 | 2008-10-24 | 2d | 0d | Dora Hermann [50%]; Labor; Daniel Penn | 20h | 337.4 | 337.4 |  |  |
| 86 | 3.13 | Fertige Filme an Vertrieb ausliefern | 1d | 2008-11-07 | 2008-11-10 | 85 | 2008-10-24 | 2008-10-27 | 1d | 0d | Michael Patten | 8h | 200 | 200 |  |  |
