# Parnell Aerospace Promo

Schedule from MS Project, 2008-04-18 to 2008-06-02, costs in €.
Southridge Video

## Calendars

- Standard: Mon-Fri 08:00-12:00, 13:00-17:00; Sat-Sun off.

## Resources

| Resource | Rate | Cost per use |
| --- | --- | --- |
| Adam Barr | 25 |  |
| Kim Bergmann | 17 |  |
| Thomas Karle | 22 |  |
| Johanna Fuller | 17 |  |
| Stephanie Härtel | 8 |  |
| Susanne Jäger | 9.5 |  |
| Jennifer Luner | 14 |  |
| Lorraine Naumann | 15 |  |
| Peter Porzuczek | 40 |  |
| Denis Steiner | 14 |  |
| MC-Orchester | 2000 | 500 |
| Lakes & Söhne |  | 250 |
| Fabrikam GmbH Soundstudio | 200 |  |
| Patrizia Broers | 16.5 |  |
| Matthias Dunker | 12 |  |
| Stefan Falk | 14 |  |
| Johannes Ganio | 22 |  |
| Sandra Haller | 40 |  |
| Richard Kaplan | 32 |  |
| Maria Anne Kobylka | 8 |  |

## Schedule

| ID | Task | Type | Duration | Start | Finish | Predecessors | Total slack | Resources | Work | Cost |
| --- | --- | --- | --- | --- | --- | --- | --- | --- | --- | --- |
| 1 | Soundtrack an Mag übertragen |  | 14d | 2008-04-18 | 2008-05-07 |  | 0d | Denis Steiner [50%] | 56h | 784 |
| 2 | Musik aufnehmen |  | 7d | 2008-05-01 | 2008-05-09 | 1FS-5d | 0d | MC-Orchester; Kim Bergmann; Peter Porzuczek | 168h | 115,692 |
| 3 | Sound synchronisieren |  | 1.5d | 2008-05-12 | 2008-05-13 | 2 | 0d | Susanne Jäger; Peter Porzuczek | 24h | 594 |
| 4 | Mixen |  | 7d | 2008-05-13 | 2008-05-22 | 3 | 0d | Peter Porzuczek; Susanne Jäger; Adam Barr | 168h | 4,172 |
| 5 | Effekte hinzufügen |  | 3d | 2008-05-22 | 2008-05-27 | 4 | 0d | Thomas Karle | 24h | 528 |
| 6 | Optische Spur hinzufügen |  | 1d | 2008-05-22 | 2008-05-23 | 4 | 2d | Kim Bergmann; Johanna Fuller | 16h | 272 |
| 7 | Spuren aufteilen |  | 3d | 2008-05-27 | 2008-05-30 | 6, 5 | 0d | Stephanie Härtel | 24h | 192 |
| 8 | Sprechtext hinzufügen |  | 1.33d | 2008-05-30 | 2008-06-02 | 7 | 0d | Kim Bergmann; Susanne Jäger; Fabrikam GmbH Soundstudio | 32h | 2,415.99 |
| 9 | Master freigeben | milestone | 0d | 2008-06-02 | 2008-06-02 | 8 | 0d |  |  |  |
