# Parnell Aerospace Promo

Schedule from MS Project, 2008-04-28 to 2008-06-10, costs in €.
Industriefilm GmbH

## Calendars

- Standard: Mon-Fri 08:00-12:00, 13:00-17:00; Sat-Sun off.

## Resources

| Resource | Rate | Cost per use |
| --- | --- | --- |
| Fabrikam GmbH Soundstudio | 200 |  |
| Kim Bergmann | 17 |  |
| Adam Barr | 25 |  |
| Denis Steiner | 14 |  |
| Johanna Fuller | 17 |  |
| MC-Orchester | 2000 | 500 |
| Peter Porzuczek | 40 |  |
| Stephanie Härtel | 8 |  |
| Susanne Jäger | 9.5 |  |
| Thomas Karle | 22 |  |

## Schedule

| ID | Task | Type | Duration | Start | Finish | Predecessors | Total slack | Constraint | Resources | Work | Cost |
| --- | --- | --- | --- | --- | --- | --- | --- | --- | --- | --- | --- |
| 1 | Soundtrack an Mag übertragen |  | 14d | 2008-04-28 | 2008-05-15 |  | 0d |  | Denis Steiner [50%] | 56h | 784 |
| 2 | Musik aufnehmen |  | 7d | 2008-05-09 | 2008-05-19 | 1FS-5d | 0d | start no earlier than 2008-05-09 | MC-Orchester; Kim Bergmann; Peter Porzuczek | 168h | 115,692 |
| 3 | Sound synchronisieren |  | 1.5d | 2008-05-20 | 2008-05-21 | 2 | 0d |  | Susanne Jäger; Peter Porzuczek | 24h | 594 |
| 4 | Mixen |  | 7d | 2008-05-21 | 2008-05-30 | 3 | 0d |  | Peter Porzuczek; Susanne Jäger; Adam Barr | 168h | 4,172 |
| 5 | Effekte hinzufügen |  | 3d | 2008-05-30 | 2008-06-04 | 4 | 0d |  | Thomas Karle | 24h | 528 |
| 6 | Optische Spur hinzufügen |  | 1d | 2008-05-30 | 2008-06-02 | 4 | 2d |  | Kim Bergmann; Johanna Fuller | 16h | 272 |
| 7 | Spuren aufteilen |  | 3d | 2008-06-04 | 2008-06-09 | 6, 5 | 0d |  | Stephanie Härtel | 24h | 192 |
| 8 | Sprechtext hinzufügen |  | 1.33d | 2008-06-09 | 2008-06-10 | 7 | 0d |  | Kim Bergmann; Susanne Jäger; Fabrikam GmbH Soundstudio | 32h | 2,415.99 |
| 9 | Master freigeben | milestone | 0d | 2008-06-10 | 2008-06-10 | 8 | 0d |  |  |  |  |
