# Wingtip Toys Werbespot

Schedule from MS Project, 2008-05-05 to 2008-07-15, costs in €.
Industriefilm GmbH

## Calendars

- Standard: Mon-Fri 08:00-12:00, 13:00-17:00; Sat-Sun off.

## Resources

| Resource | Rate |
| --- | --- |
| Kim Bergmann | 17 |
| Patrizia Broers | 16.5 |
| Matthias Dunker | 12 |
| Stefan Falk | 14 |
| Johannes Ganio | 22 |
| Sandra Haller | 40 |
| Richard Kaplan | 32 |
| Maria Anne Kobylka | 8 |
| Jakob Meier | 12 |
| Patti Mintz | 22 |
| Lisa Osten | 21 |
| Johannes Roller | 18 |
| Lana Sailer | 12 |
| Gerd Vaude | 11 |
| Susie Weiss | 11.5 |
| Raymond Zambrowski | 21.75 |
| Fabrikam GmbH Soundstudio | 200 |

## Schedule

| ID | Task | Type | Duration | Start | Finish | Predecessors | Total slack | Resources | Work | Cost |
| --- | --- | --- | --- | --- | --- | --- | --- | --- | --- | --- |
| 1 | Filmmaterial sichten |  | 1w | 2008-05-05 | 2008-05-09 |  | 0d | Patrizia Broers [50%]; Johannes Ganio; Maria Anne Kobylka | 100h | 1,530 |
| 2 | Sprechtext grob festlegen |  | 4d | 2008-05-07 | 2008-05-12 | 1FS-3d | 0d | Kim Bergmann; Matthias Dunker | 64h | 928 |
| 3 | Filmsequenzen schriftlich bearbeiten |  | 2w | 2008-05-13 | 2008-05-26 | 2 | 0d | Kim Bergmann; Johannes Ganio; Maria Anne Kobylka | 240h | 3,760 |
| 4 | Grobschnitt |  | 1w | 2008-05-27 | 2008-06-02 | 3 | 0d | Kim Bergmann; Lana Sailer | 80h | 1,160 |
| 5 | Detailschnitt |  | 2w | 2008-06-03 | 2008-06-16 | 4 | 0d | Patrizia Broers [50%]; Sandra Haller | 120h | 3,860 |
| 6 | Formelle Abnahmevorführung |  | 1d | 2008-06-17 | 2008-06-17 | 5 | 0d | Kim Bergmann; Stefan Falk; Maria Anne Kobylka; Raymond Zambrowski | 32h | 486 |
| 7 | Text aufnehmen |  | 1w | 2008-06-18 | 2008-06-24 | 6 | 0d | Fabrikam GmbH Soundstudio; Johannes Ganio | 80h | 8,880 |
| 8 | Vor- und Abspann fertig stellen |  | 1w | 2008-06-25 | 2008-07-01 | 7 | 0d | Gerd Vaude; Maria Anne Kobylka | 80h | 760 |
| 9 | Soundtrack fertig stellen |  | 0.67w | 2008-06-30 | 2008-07-03 | 8FS-2d | 0d | Kim Bergmann; Johannes Roller; Lana Sailer | 80h | 1,253.33 |
| 10 | Negativ ziehen |  | 3d | 2008-07-03 | 2008-07-08 | 9 | 0d | Lana Sailer | 24h | 288 |
| 11 | Master von Audiokassette duplizieren |  | 4d | 2008-07-08 | 2008-07-14 | 10 | 0d | Susie Weiss | 32h | 368 |
| 12 | Synchronisationsmaster auf Audiokassette speichern |  | 1d | 2008-07-14 | 2008-07-15 | 11 | 0d | Susie Weiss | 8h | 92 |
| 13 | Fertige Flme an Vertrieb ausliefern | milestone | 0d | 2008-07-15 | 2008-07-15 | 12 | 0d |  |  |  |
